# Produtividade CIASE

Schedule from MS Project, 2010-06-01 to 2011-09-24, costs in R$.

## Calendars

- Padrão: Mon-Sun 08:00-12:00, 13:00-17:00.

## Resources

| Resource |
| --- |
| 1 |
| 2 |
| CARPINTEIRO |
| SERVENTE |
| AJUDANTE MONTADOR ELETROMECÂNICO |
| PEDREIRO |
| 3 |
| 4 |
| AJUDANTE |
| PINTOR |
| FERREIRO |
| 5 |
| TELHADISTA |
| COLOCADOR |
| GESSEIRO |
| INSTALAÇÃO |
| AZULEJISTA |
| LADRILHISTA |
| GRANITEIRO |
| ENCANADOR |
| 6 |
| CALCETEIRO |
| GRANILITEIRO |
| fernanda |
| JARDINEIRO |
| ENCANDOR |

## Schedule

| ID | WBS | Task | Duration | Start | Finish | Predecessors | Total slack | Free slack | Resources | Work | Cost |
| --- | --- | --- | --- | --- | --- | --- | --- | --- | --- | --- | --- |
| 1 | 1 | **CIASE/ CENTRO INTEGRADO DE ATENDIMENTO SÓCIO-EDUCATIVO** | 480d | 2010-06-01 | 2011-09-24 |  | 0d |  |  | 83033.3h | 10,977,901.82 |
| 2 | 1.1 | **ASSINATURA DO CONTRATO** | 30d | 2010-06-01 | 2010-07-01 |  | 90d |  |  |  |  |
| 3 | 1.1.1 | Emissão da Ordem de serviço | 30d | 2010-06-01 | 2010-07-01 |  | 90d | 0d |  |  |  |
| 4 | 1.2 | **EQUIPE PARA ADMINISTRAÇÃO LOCAL** | 360d | 2010-07-01 | 2011-06-26 |  | 90d |  |  |  | 417,654.96 |
| 5 | 1.2.1 | Engenheiro Senior (Coef. mensal = 1,00) | 360d | 2010-07-01 | 2011-06-26 | 3 | 90d |  |  |  | 159,998.88 |
| 6 | 1.2.2 | Mestre de Obras, encarregado (Coeficiente mensal = 1,00) | 360d | 2010-07-01 | 2011-06-26 | 3 | 90d |  |  |  | 33,889.2 |
| 7 | 1.2.3 | Encarregado de turma (Coeficiente mensal = 2,00) | 360d | 2010-07-01 | 2011-06-26 | 3 | 90d |  |  |  | 52,063.44 |
| 8 | 1.2.4 | Técnico de Edificações (Coeficiente mensal = 2,00) | 360d | 2010-07-01 | 2011-06-26 | 3 | 90d |  |  |  | 70,886.4 |
| 9 | 1.2.5 | Tecnico em Segurança do Trabalho (Coef. mensal = 1,00) | 360d | 2010-07-01 | 2011-06-26 | 3 | 90d |  |  |  | 40,896 |
| 10 | 1.2.6 | Almoxarife (Coeficiente mensal = 1,00) | 360d | 2010-07-01 | 2011-06-26 | 3 | 90d |  |  |  | 18,714 |
| 11 | 1.2.7 | Vigia (Coef. mensal = 3,00) | 360d | 2010-07-01 | 2011-06-26 | 3 | 90d |  |  |  | 41,207.04 |
| 12 | 1.3 | **SERVIÇOS PRELIMINARES** | 229d | 2010-07-01 | 2011-02-15 |  | 221d |  |  | 480h | 40,148.53 |
| 13 | 1.3.1 | **Andaime metálico para Fachada** | 30d | 2011-01-16 | 2011-02-15 |  | 221d |  |  |  | 5,105.02 |
| 14 | 1.3.1.1 | Locação de andaime metálico para fachada - tipo torre (aluguel mensal) | 30d | 2011-01-16 | 2011-02-15 | 84 | 221d |  |  |  | 5,105.02 |
| 15 | 1.3.2 | **Demolições e retiradas** | 7d | 2010-07-01 | 2010-07-08 |  | 376d | 0d |  | 240h | 21,118.19 |
| 16 | 1.3.2.1 | Remoção mecanizada de revestimento betuminoso (asfalto), inclusive carga e transporte da carga ate 10 km | 7d | 2010-07-01 | 2010-07-08 | 3 | 376d |  |  |  | 9,454 |
| 17 | 1.3.2.2 | Raspagem e limpeza do terreno (manual) | 7d | 2010-07-01 | 2010-07-08 | 3 | 376d |  | SERVENTE | 56h | 7,134.96 |
| 18 | 1.3.2.3 | Corte e destocamento de árvores com diâmetro de até 15cm | 3d | 2010-07-01 | 2010-07-04 | 3 | 380d |  | SERVENTE | 24h | 242.52 |
| 19 | 1.3.2.4 | Corte e destocamento de árvores com diâmetro superior a 30 cm | 3d | 2010-07-01 | 2010-07-04 | 3 | 380d |  | SERVENTE | 24h | 150.81 |
| 20 | 1.3.2.5 | Retirada de poste de iluminação em concreto com alturas de 7 a 12m | 1d | 2010-07-01 | 2010-07-02 | 3 | 382d |  | AJUDANTE MONTADOR ELETROMECÂNICO | 8h | 628.08 |
| 21 | 1.3.2.6 | Retirada de meio-fio | 7d | 2010-07-01 | 2010-07-08 | 3 | 376d |  | PEDREIRO; SERVENTE | 112h | 2,661.85 |
| 22 | 1.3.2.7 | Retirada de grades, gradis | 2d | 2010-07-01 | 2010-07-03 | 3 | 381d |  | SERVENTE | 16h | 845.96 |
| 23 | 1.3.3 | **Locação da Obra** | 7d | 2010-07-21 | 2010-07-28 |  | 423d |  |  | 240h | 13,925.33 |
| 24 | 1.3.3.1 | Locação de obra com gabarito de madeira | 7d | 2010-07-21 | 2010-07-28 | 30 | 423d |  | AJUDANTE; CARPINTEIRO; PINTOR; SERVENTE | 224h | 13,301.47 |
| 25 | 1.3.3.2 | Equipe topográfica para serviços simples de locação e nivelamento (incluindo equipamento, transporte e profissionais nível médio) | 1d | 2010-07-21 | 2010-07-22 | 30 | 429d |  | CARPINTEIRO; SERVENTE | 16h | 623.86 |

| ID | WBS | Task | Duration | Start | Finish | Predecessors | Total slack | Free slack | Resources | Work | Cost |
| --- | --- | --- | --- | --- | --- | --- | --- | --- | --- | --- | --- |
| 26 | 1.4 | **INSTALAÇÃO DO CANTEIRO DE OBRAS** | 20d | 2010-07-01 | 2010-07-21 |  | 423d |  |  | 998.2h | 87,055.79 |
| 27 | 1.4.1 | **Tapumes e Placa de Obra** | 7d | 2010-07-08 | 2010-07-15 |  | 436d |  |  | 998.2h | 38,861.64 |
| 28 | 1.4.1.1 | Tapume de chapa de aço galvanizado Nr.26 USG, pintada, com 2,00m de altura e com requadro de madeira 2,5 x 5,0cm e pontalete 8 x 8cm a cada 1m, para utilização 1 vez | 7d | 2010-07-08 | 2010-07-15 | 15 | 436d |  | AJUDANTE [600%]; CARPINTEIRO [600%]; PINTOR [600%]; SERVENTE [600%] | 982.2h | 33,738.48 |
| 29 | 1.4.1.2 | Placa de obra nas dimensões de 6.0 x 3.0 m | 1d | 2010-07-08 | 2010-07-09 | 15 | 442d |  | CARPINTEIRO; SERVENTE | 16h | 5,123.16 |
| 30 | 1.4.2 | **Instalação do Canteiro de Obras (Utilização 1 vez)** | 20d | 2010-07-01 | 2010-07-21 |  | 423d | 0d |  |  | 48,194.15 |
| 31 | 1.4.2.1 | Barracão para escritório com sanitário área de 14.50 m2, de chapa de compens. 12mm e pontalete 8x8cm, piso cimentado e cobertura de telha de fibroc. 6mm, incl. ponto de luz e cx. de inspeção, conf. projeto (1 utilização) | 20d | 2010-07-01 | 2010-07-21 | 3 | 423d |  |  |  | 5,666.89 |
| 32 | 1.4.2.2 | Barracão para almoxarifado área de 10.90m2, de chapa de compensado de 12mm e pontalete 8x8cm, piso cimentado e cobertura de telhas de fibrocimento de 6mm, incl. ponto de luz, conf. projeto (1 utilização) | 20d | 2010-07-01 | 2010-07-21 | 3 | 423d |  |  |  | 3,086.88 |
| 33 | 1.4.2.3 | Barracão para depósito de cimento área de 10.90m2, de chapa de compensado 12mm e pontaletes 8x8cm, piso cimentado e cobertura de telhas de fibrocimento de 6mm, inclusive ponto de luz, conf. projeto (1 utilização) | 20d | 2010-07-01 | 2010-07-21 | 3 | 423d |  |  |  | 2,736.66 |
| 34 | 1.4.2.4 | Refeitório com paredes de chapa de compens. 12mm e pontaletes 8x8cm, piso ciment. e cob. de telhas fibroc. 6mm, incl. ponto de luz e cx. de inspeção (cons. 1.21 m2/func./turno), conf. projeto (1 utilização) | 20d | 2010-07-01 | 2010-07-21 | 3 | 423d |  |  |  | 11,642.14 |
| 35 | 1.4.2.5 | Unidade de sanitário e vestiário de 20 a 40 func. área 25.40m2, paredes de chapa compens. 12mm e pontalete 8x8cm, piso cimentado, cobert. telha fibroc. 6mm, incl. inst. de luz e cx. de inspeção, conf. projeto (1 utilização) | 20d | 2010-07-01 | 2010-07-21 | 3 | 423d |  |  |  | 11,193.01 |
| 36 | 1.4.2.6 | Galpão para serraria e carpintaria área 12.00m2, em peça de madeira 8x8cm e contraventamento de 5x7cm, cobertura de telha de fibroc. de 6mm, inclusive ponto e cabo de alimentação da máquina, conf. projeto (1 utilização) | 20d | 2010-07-01 | 2010-07-21 | 3 | 423d |  |  |  | 1,388.88 |
| 37 | 1.4.2.7 | Galpão para corte e armação com área de 6.00m2, em peças de madeira 8x8cm e contraventamento de 5x7cm, cobertura de telhas de fibroc. de 6mm, inclusive ponto e cabo de alimentação da máquina, conf. projeto (1 utilização) | 20d | 2010-07-01 | 2010-07-21 | 3 | 423d |  |  |  | 896.58 |
| 38 | 1.4.2.8 | Reservatório de fibra de vidro de 1000 L, incl. suporte em madeira de 7x12cm e 8x7cm, elevado de 4m, conf. projeto (1 utilização) | 20d | 2010-07-01 | 2010-07-21 | 3 | 423d |  |  |  | 1,021.31 |
| 39 | 1.4.2.9 | Rede de água com padrão de entrada d'água diâm. 3/4", conf. espec. CESAN, incl. tubos e conexões para alimentação, distribuição, extravasor e limpeza, cons. o padrão a 25m, conf. projeto (1 utilização) | 20d | 2010-07-01 | 2010-07-21 | 3 | 423d |  |  |  | 589.75 |
| 40 | 1.4.2.10 | Rede de luz, incl. padrão entrada de energia trifás., cabo de ligação até barracões, quadro de distrib., disj. e chave de força (quando necessário), cons. 20m entre padrão entrada e QDG, conf. projeto (1 utilização) | 20d | 2010-07-01 | 2010-07-21 | 3 | 423d |  |  |  | 5,631.8 |
| 41 | 1.4.2.11 | Rede de esgoto, contendo fossa e filtro, inclusive tubos e conexões de ligação entre caixas, considerando distância de 25m, conforme projeto (1 utilização) | 20d | 2010-07-01 | 2010-07-21 | 3 | 423d |  |  |  | 4,340.25 |
| 42 | 1.5 | **TERRAPLENAGEM DO TERRENO** | 5d | 2010-07-08 | 2010-07-13 |  | 376d | 0d |  | 216h | 49,572.15 |
| 43 | 1.5.1 | Escavação mecânica em material de 1a. categoria | 5d | 2010-07-08 | 2010-07-13 | 15 | 376d |  | SERVENTE | 40h | 7,856.8 |
| 44 | 1.5.2 | Espalhamento manual de material escavado de 1ª categoria | 5d | 2010-07-08 | 2010-07-13 | 15 | 376d |  | SERVENTE | 40h | 2,309.66 |
| 45 | 1.5.3 | Aterro de terreno em areia, inclusive aquisição em jazida, carga, transporte com distância até 15 Km, descarga, espalhamento mecânico e adensamento hidráulico com caminhão pipa | 5d | 2010-07-08 | 2010-07-13 | 15 | 376d |  | SERVENTE [300%] | 120h | 16,902.58 |
| 46 | 1.5.4 | Bota-Fora de material escavado das cavas de fundação, inclusive matéria orgânica (DMT 10Km) considerando empolamento de 30% | 2d | 2010-07-08 | 2010-07-10 | 15 | 379d |  | SERVENTE | 16h | 22,503.11 |
| 47 | 1.6 | **LOCAÇÃO DE ESTACAS** | 2d | 2010-07-13 | 2010-07-15 |  | 376d |  |  |  | 1,559.65 |
| 48 | 1.6.1 | Equipe topográfica para serviços simples de locação e nivelamento (incluindo equipamento, transporte e profissionais nível médio) | 2d | 2010-07-13 | 2010-07-15 | 42 | 376d | 0d |  |  | 1,559.65 |
| 49 | 1.7 | **ESTAQUEAMENTO** | 60d | 2010-07-15 | 2010-09-13 |  | 376d | 0d |  |  | 497,189.33 |
| 50 | 1.7.1 | Mobilização e desmobilização de equipamentos para cravação de estacas pré-moldadas de concreto | 60d | 2010-07-15 | 2010-09-13 | 48 | 376d |  |  |  | 7,168 |
| 51 | 1.7.2 | Estaca pré-moldada de concreto Ø 18 | 60d | 2010-07-15 | 2010-09-13 | 48 | 376d |  |  |  | 28,577.99 |
| 52 | 1.7.3 | Estaca pré-moldada de concreto Ø 26 | 60d | 2010-07-15 | 2010-09-13 | 48 | 376d |  |  |  | 164,809.26 |
| 53 | 1.7.4 | Estaca pré-moldada de concreto Ø 33 | 60d | 2010-07-15 | 2010-09-13 | 48 | 376d |  |  |  | 130,033.8 |
| 54 | 1.7.5 | Cravação de estaca pré-moldada de concreto Ø18 | 60d | 2010-07-15 | 2010-09-13 | 48 | 376d |  |  |  | 21,532.16 |
| 55 | 1.7.6 | Cravação de estaca pré-moldada de concreto Ø26 | 60d | 2010-07-15 | 2010-09-13 | 48 | 376d |  |  |  | 80,847.36 |
| 56 | 1.7.7 | Cravação de estaca pré-moldada de concreto Ø33 | 60d | 2010-07-15 | 2010-09-13 | 48 | 376d |  |  |  | 50,918.4 |
| 57 | 1.7.8 | Emenda para estaca pré-moldada de concreto Ø18 | 60d | 2010-07-15 | 2010-09-13 | 48 | 376d |  |  |  | 1,248 |
| 58 | 1.7.9 | Emenda para estaca pré-moldada de concreto Ø26 | 60d | 2010-07-15 | 2010-09-13 | 48 | 376d |  |  |  | 5,114.88 |
| 59 | 1.7.10 | Emenda para estaca pré-moldada de concreto Ø33 | 60d | 2010-07-15 | 2010-09-13 | 48 | 376d |  |  |  | 2,828.66 |
| 60 | 1.7.11 | Arrasamento de estaca pré-moldada de concreto Ø18 | 60d | 2010-07-15 | 2010-09-13 | 48 | 376d |  |  |  | 609.18 |
| 61 | 1.7.12 | Arrasamento de estaca pré-moldada de concreto Ø26 | 60d | 2010-07-15 | 2010-09-13 | 48 | 376d |  |  |  | 2,197.8 |
| 62 | 1.7.13 | Arrasamento de estaca pré-moldada de concreto Ø33 | 60d | 2010-07-15 | 2010-09-13 | 48 | 376d |  |  |  | 1,303.84 |

| ID | WBS | Task | Duration | Start | Finish | Predecessors | Total slack | Free slack | Resources | Work | Cost |
| --- | --- | --- | --- | --- | --- | --- | --- | --- | --- | --- | --- |
| 63 | 1.8 | **INFRA-ESTRUTURA** | 69d | 2010-07-25 | 2010-10-02 |  | 116d |  |  | 11530h | 667,427.69 |
| 64 | 1.8.1 | **Escavação** | 52d | 2010-07-25 | 2010-09-15 |  | 374d | 0d |  | 416h | 5,601.23 |
| 65 | 1.8.1.1 | Escavação manual em material de 1a. categoria, até 1.50 m de profundidade | 52d | 2010-07-25 | 2010-09-15 | 49SS+10d | 374d |  | SERVENTE | 416h | 3,369.31 |
| 66 | 1.8.1.2 | Escavação mecânica em material de 1a. categoria | 2d | 2010-07-25 | 2010-07-27 | 49SS+10d | 424d |  |  |  | 2,231.92 |
| 67 | 1.8.2 | **Reaterro** | 47d | 2010-08-15 | 2010-10-01 |  | 357d | 0d |  | 376h | 1,033.98 |
| 68 | 1.8.2.1 | Reaterro apiloado de cavas de fundação, em camadas de 20 cm | 47d | 2010-08-15 | 2010-10-01 | 81SS+10d | 357d |  | SERVENTE | 376h | 1,033.98 |
| 69 | 1.8.3 | **Transportes** | 1d | 2010-10-01 | 2010-10-02 |  | 357d |  |  | 8h | 3,273.6 |
| 70 | 1.8.3.1 | Bota-Fora de material escavado das cavas de fundação, inclusive matéria orgânica (DMT 10Km) considerando empolamento de 30% | 1d | 2010-10-01 | 2010-10-02 | 67 | 357d |  | SERVENTE | 8h | 3,273.6 |
| 71 | 1.8.4 | **Concreto magro** | 49d | 2010-08-01 | 2010-09-19 |  | 370d | 0d |  | 1397.97h | 35,665.29 |
| 72 | 1.8.4.1 | Fornecimento, preparo e aplicação de concreto magro com consumo mínimo de cimento de 250 kg/m3 (brita 1 e 2) - (5% de perdas já incluso no custo) | 49d | 2010-08-01 | 2010-09-19 | 64SS+7d | 370d |  | PEDREIRO [300%]; SERVENTE [300%] | 1397.97h | 35,665.29 |
| 73 | 1.8.5 | **Forma** | 49d | 2010-08-03 | 2010-09-21 |  | 368d | 0d |  | 784h | 20,824 |
| 74 | 1.8.5.1 | Forma de tábua de madeira de 2.5 x 30.0 cm para fundações, levando-se em conta a utilização 2 vezes (incluido o material, corte, montagem, escoramento e desforma) | 49d | 2010-08-03 | 2010-09-21 | 71SS+2d | 368d |  | AJUDANTE; CARPINTEIRO | 784h | 20,824 |
| 75 | 1.8.6 | **Armação** | 49d | 2010-08-03 | 2010-09-21 |  | 368d | 0d |  | 3136h | 125,247.61 |
| 76 | 1.8.6.1 | Fornecimento, dobragem e colocação em forma, de armadura CA-50 A média, diâmetro de 6.3 a 10.0 mm | 49d | 2010-08-03 | 2010-09-21 | 73SS | 368d |  | AJUDANTE; FERREIRO | 784h | 22,224.42 |
| 77 | 1.8.6.2 | Fornecimento, dobragem e colocação em fôrma, de armadura CA-50 A grossa diâmetro de 12.5 a 25.0 mm (1/2 a 1") | 49d | 2010-08-03 | 2010-09-21 | 73SS | 368d |  | AJUDANTE; FERREIRO | 784h | 42,466.71 |
| 78 | 1.8.6.3 | Fornecimento, dobragem e colocação em fôrma, de armadura CA-60 B fina, diâmetro de 4.0 a 7.0mm | 49d | 2010-08-03 | 2010-09-21 | 73SS | 368d |  | AJUDANTE; FERREIRO | 784h | 60,189.6 |
| 79 | 1.8.6.4 | Tela soldada em aço Q 196 CA-60 B, com malha de 10 x 10 cm, para armação (Casa de Gás) | 49d | 2010-08-03 | 2010-09-21 | 73SS | 368d |  | AJUDANTE; FERREIRO | 784h | 43.8 |
| 80 | 1.8.6.5 | Tela soldada em aço Q 138 CA-60 B, com malha de 10 x 10 cm, para armação (para as camas em concreto dos alojamentos) | 49d | 2010-08-03 | 2010-09-21 | 73SS | 368d |  |  |  | 323.08 |
| 81 | 1.8.7 | **Concreto usinado** | 49d | 2010-08-05 | 2010-09-23 |  | 105d | 0d |  | 5412h | 475,781.96 |
| 82 | 1.8.7.1 | Fornecimento e aplicação de concreto USINADO Fck=30 MPa - considerando lançamento MANUAL para INFRA-ESTRUTURA (5% de perdas já incluído no custo) | 49d | 2010-08-05 | 2010-09-23 | 75SS+2d | 105d |  | PEDREIRO [800%]; SERVENTE [800%] | 4236h | 41,753.8 |
| 83 | 1.8.7.2 | Laje do térreo em concreto armado com Fck=30 Mpa, camada única de esp. 20 cm, concreto magro esp. 5 cm, malha dupla Q503 CA-50A, lona plástica, acabamento superficial c/ rotalisador | 49d | 2010-08-05 | 2010-09-23 | 75SS+2d | 105d |  | SERVENTE [300%] | 1176h | 434,028.16 |
| 84 | 1.9 | **SUPER-ESTRUTURA** | 132d | 2010-09-06 | 2011-01-16 |  | 122d | 0d |  | 3264h | 1,709,204.3 |
| 85 | 1.9.1 | **1ª Laje** | 39d | 2010-09-06 | 2010-10-15 |  | 104d | 0d |  | 816h | 427,301.08 |
| 86 | 1.9.1.1 | **Estrutura metálica** | 10d | 2010-09-06 | 2010-09-16 |  | 133d |  |  |  | 105,123.48 |
| 87 | 1.9.1.1.1 | Pilares metálicos com seções W - 360 x 79,0 kg/m e W - 360 x 122,0 kg/m em aço ASTM A-572 GR 50, inclusive chumbadores de 3/4", chapas metálicas e tratamento com jateamento mais pintura, conforme preojeto, inclusive fornecimento e montagem | 10d | 2010-09-06 | 2010-09-16 | 81FF-7d | 133d |  |  |  | 105,123.48 |

| ID | WBS | Task | Duration | Start | Finish | Predecessors | Total slack | Free slack | Resources | Work | Cost |
| --- | --- | --- | --- | --- | --- | --- | --- | --- | --- | --- | --- |
| 88 | 1.9.1.2 | **Escoramento metálico** | 6d | 2010-09-23 | 2010-09-29 |  | 105d | 0d |  |  | 25,402.05 |
| 89 | 1.9.1.2.1 | Escoramento metálico | 6d | 2010-09-23 | 2010-09-29 | 81 | 105d |  |  |  | 25,402.05 |
| 90 | 1.9.1.3 | **Forma** | 15d | 2010-09-29 | 2010-10-14 |  | 105d | 0d |  | 240h | 41,639.67 |
| 91 | 1.9.1.3.1 | Forma de chapas madeira compensada resinada, esp. 12mm, levando-se em conta a utilização 3 vezes, reforçadas com sarrafos de madeira de 2.5 x 10.0cm (incl material, corte, montagem, desforma, exclusive escoramento) | 15d | 2010-09-29 | 2010-10-14 | 88 | 105d |  | AJUDANTE; CARPINTEIRO | 240h | 29,628.06 |
| 92 | 1.9.1.3.2 | Forma de chapas madeira compensada resinada, esp. 12mm, levando-se em conta a utilização 3 vezes, reforçadas com sarrafos de madeira de 2.5 x 10.0cm (incl material, corte, montagem, escoras em eucalipto e desforma) | 15d | 2010-09-29 | 2010-10-14 | 88 | 105d |  |  |  | 12,011.61 |
| 93 | 1.9.1.4 | **Armação** | 7d | 2010-10-07 | 2010-10-14 |  | 104d | 0d |  | 560h | 143,520.2 |
| 94 | 1.9.1.4.1 | Fornecimento, dobragem e colocação em fôrma, de armadura CA-50 A média, diâmetro de 6.3 a 10.0 mm | 7d | 2010-10-07 | 2010-10-14 | 90SS+8d | 104d |  | AJUDANTE; FERREIRO | 112h | 14,701.95 |
| 95 | 1.9.1.4.2 | Fornecimento, dobragem e colocação em fôrma, de armadura CA-50 A grossa, diâmetro de 12.5 a 25.0mm | 7d | 2010-10-07 | 2010-10-14 | 90SS+8d | 104d |  | AJUDANTE; FERREIRO | 112h | 35,776.62 |
| 96 | 1.9.1.4.3 | Fornecimento, dobragem e colocação em forma, de armadura CA-60 B fina, diâmetro de 4.0 a 7.0mm | 7d | 2010-10-07 | 2010-10-14 | 90SS+8d | 104d |  | AJUDANTE; FERREIRO | 112h | 3,777.35 |
| 97 | 1.9.1.4.4 | Tela soldada em aço Q 138 CA-60 B, com malha de 10 x 10 cm, para armação | 7d | 2010-10-07 | 2010-10-14 | 90SS+8d | 104d |  | AJUDANTE; FERREIRO | 112h | 19,923.02 |
| 98 | 1.9.1.4.5 | Indice de preço p/ fornec. cordoalha engraxada CP 190 RB 12.7 mm (1/2"),incl. serviço protensão, c/ todos os acessórios p/o sistema de ancoragem ativa e passiva, em lajes esp= 18cm e mão-de-obra de apoio | 7d | 2010-10-07 | 2010-10-14 | 90SS+8d | 104d |  | AJUDANTE; PEDREIRO | 112h | 69,341.26 |
| 99 | 1.9.1.5 | **Concreto usinado** | 1d | 2010-10-14 | 2010-10-15 |  | 104d | 0d |  | 16h | 111,615.67 |
| 100 | 1.9.1.5.1 | Fornecimento e aplicação de concreto USINADO Fck=30 MPa - considerando BOMBEAMENTO (5% de perdas já incluído no custo) (6% de taxa p/ concr. bombeavel) | 1d | 2010-10-14 | 2010-10-15 | 93 | 104d |  | PEDREIRO; SERVENTE | 16h | 111,615.67 |
| 101 | 1.9.2 | **2ª Laje** | 32d | 2010-10-14 | 2010-11-15 |  | 212d |  |  | 816h | 427,301.08 |
| 102 | 1.9.2.1 | **Estrutura metálica** | 10d | 2010-10-14 | 2010-10-24 |  | 305d |  |  |  | 105,123.48 |
| 103 | 1.9.2.1.1 | Pilares metálicos com seções W - 360 x 79,0 kg/m e W - 360 x 122,0 kg/m em aço ASTM A-572 GR 50, inclusive chumbadores de 3/4", chapas metálicas e tratamento com jateamento mais pintura, conforme preojeto, inclusive fornecimento e montagem | 10d | 2010-10-14 | 2010-10-24 | 90 | 305d |  |  |  | 105,123.48 |
| 104 | 1.9.2.2 | **Escoramento metálico** | 6d | 2010-10-22 | 2010-10-28 |  | 276d | 0d |  |  | 25,402.05 |
| 105 | 1.9.2.2.1 | Escoramento metálico | 6d | 2010-10-22 | 2010-10-28 | 99FS+7d | 276d |  |  |  | 25,402.05 |
| 106 | 1.9.2.3 | **Forma** | 15d | 2010-10-28 | 2010-11-12 |  | 276d | 0d |  | 240h | 41,639.67 |
| 107 | 1.9.2.3.1 | Forma de chapas madeira compensada resinada, esp. 12mm, levando-se em conta a utilização 3 vezes, reforçadas com sarrafos de madeira de 2.5 x 10.0cm (incl material, corte, montagem, desforma, exclusive escoramento) | 15d | 2010-10-28 | 2010-11-12 | 104 | 276d |  | AJUDANTE; CARPINTEIRO | 240h | 29,628.06 |
| 108 | 1.9.2.3.2 | Forma de chapas madeira compensada resinada, esp. 12mm, levando-se em conta a utilização 3 vezes, reforçadas com sarrafos de madeira de 2.5 x 10.0cm (incl material, corte, montagem, escoras em eucalipto e desforma) | 15d | 2010-10-28 | 2010-11-12 | 104 | 276d |  |  |  | 12,011.61 |
| 109 | 1.9.2.4 | **Armação** | 7d | 2010-11-07 | 2010-11-14 |  | 188d | 0d |  | 560h | 143,520.2 |
| 110 | 1.9.2.4.1 | Fornecimento, dobragem e colocação em fôrma, de armadura CA-50 A média, diâmetro de 6.3 a 10.0 mm | 7d | 2010-11-07 | 2010-11-14 | 106SS+10d | 188d |  | AJUDANTE; FERREIRO | 112h | 14,701.95 |
| 111 | 1.9.2.4.2 | Fornecimento, dobragem e colocação em fôrma, de armadura CA-50 A grossa, diâmetro de 12.5 a 25.0mm | 7d | 2010-11-07 | 2010-11-14 | 106SS+10d | 188d |  | AJUDANTE; FERREIRO | 112h | 35,776.62 |
| 112 | 1.9.2.4.3 | Fornecimento, dobragem e colocação em forma, de armadura CA-60 B fina, diâmetro de 4.0 a 7.0mm | 7d | 2010-11-07 | 2010-11-14 | 106SS+10d | 188d |  | AJUDANTE; FERREIRO | 112h | 3,777.35 |
| 113 | 1.9.2.4.4 | Tela soldada em aço Q 138 CA-60 B, com malha de 10 x 10 cm, para armação | 7d | 2010-11-07 | 2010-11-14 | 106SS+10d | 188d |  | AJUDANTE; FERREIRO | 112h | 19,923.02 |
| 114 | 1.9.2.4.5 | Indice de preço p/ fornec. cordoalha engraxada CP 190 RB 12.7 mm (1/2"),incl. serviço protensão, c/ todos os acessórios p/o sistema de ancoragem ativa e passiva, em lajes esp= 18cm e mão-de-obra de apoio | 7d | 2010-11-07 | 2010-11-14 | 106SS+10d | 188d |  | AJUDANTE; PEDREIRO | 112h | 69,341.26 |

| ID | WBS | Task | Duration | Start | Finish | Predecessors | Total slack | Free slack | Resources | Work | Cost |
| --- | --- | --- | --- | --- | --- | --- | --- | --- | --- | --- | --- |
| 115 | 1.9.2.5 | **Concreto usinado** | 1d | 2010-11-14 | 2010-11-15 |  | 188d | 0d |  | 16h | 111,615.67 |
| 116 | 1.9.2.5.1 | Fornecimento e aplicação de concreto USINADO Fck=30 MPa - considerando BOMBEAMENTO (5% de perdas já incluído no custo) (6% de taxa p/ concr. bombeavel) | 1d | 2010-11-14 | 2010-11-15 | 109 | 188d |  | PEDREIRO; SERVENTE | 16h | 111,615.67 |
| 117 | 1.9.3 | **3ª Laje** | 34d | 2010-11-12 | 2010-12-16 |  | 193d |  |  | 816h | 427,301.08 |
| 118 | 1.9.3.1 | **Estrutura metálica** | 10d | 2010-11-12 | 2010-11-22 |  | 276d |  |  |  | 105,123.48 |
| 119 | 1.9.3.1.1 | Pilares metálicos com seções W - 360 x 79,0 kg/m e W - 360 x 122,0 kg/m em aço ASTM A-572 GR 50, inclusive chumbadores de 3/4", chapas metálicas e tratamento com jateamento mais pintura, conforme preojeto, inclusive fornecimento e montagem | 10d | 2010-11-12 | 2010-11-22 | 106 | 276d |  |  |  | 105,123.48 |
| 120 | 1.9.3.2 | **Escoramento metálico** | 6d | 2010-11-22 | 2010-11-28 |  | 188d | 0d |  |  | 25,402.05 |
| 121 | 1.9.3.2.1 | Escoramento metálico | 6d | 2010-11-22 | 2010-11-28 | 115FS+7d | 188d |  |  |  | 25,402.05 |
| 122 | 1.9.3.3 | **Forma** | 15d | 2010-11-28 | 2010-12-13 |  | 188d | 0d |  | 240h | 41,639.67 |
| 123 | 1.9.3.3.1 | Forma de chapas madeira compensada resinada, esp. 12mm, levando-se em conta a utilização 3 vezes, reforçadas com sarrafos de madeira de 2.5 x 10.0cm (incl material, corte, montagem, desforma, exclusive escoramento) | 15d | 2010-11-28 | 2010-12-13 | 120 | 188d |  | AJUDANTE; CARPINTEIRO | 240h | 29,628.06 |
| 124 | 1.9.3.3.2 | Forma de chapas madeira compensada resinada, esp. 12mm, levando-se em conta a utilização 3 vezes, reforçadas com sarrafos de madeira de 2.5 x 10.0cm (incl material, corte, montagem, escoras em eucalipto e desforma) | 15d | 2010-11-28 | 2010-12-13 | 120 | 188d |  |  |  | 12,011.61 |
| 125 | 1.9.3.4 | **Armação** | 7d | 2010-12-08 | 2010-12-15 |  | 167d | 0d |  | 560h | 143,520.2 |
| 126 | 1.9.3.4.1 | Fornecimento, dobragem e colocação em fôrma, de armadura CA-50 A média, diâmetro de 6.3 a 10.0 mm | 7d | 2010-12-08 | 2010-12-15 | 122SS+10d | 167d |  | AJUDANTE; FERREIRO | 112h | 14,701.95 |
| 127 | 1.9.3.4.2 | Fornecimento, dobragem e colocação em fôrma, de armadura CA-50 A grossa, diâmetro de 12.5 a 25.0mm | 7d | 2010-12-08 | 2010-12-15 | 122SS+10d | 167d |  | AJUDANTE; FERREIRO | 112h | 35,776.62 |
| 128 | 1.9.3.4.3 | Fornecimento, dobragem e colocação em forma, de armadura CA-60 B fina, diâmetro de 4.0 a 7.0mm | 7d | 2010-12-08 | 2010-12-15 | 122SS+10d | 167d |  | AJUDANTE; FERREIRO | 112h | 3,777.35 |
| 129 | 1.9.3.4.4 | Tela soldada em aço Q 138 CA-60 B, com malha de 10 x 10 cm, para armação | 7d | 2010-12-08 | 2010-12-15 | 122SS+10d | 167d |  | AJUDANTE; FERREIRO | 112h | 19,923.02 |
| 130 | 1.9.3.4.5 | Indice de preço p/ fornec. cordoalha engraxada CP 190 RB 12.7 mm (1/2"),incl. serviço protensão, c/ todos os acessórios p/o sistema de ancoragem ativa e passiva, em lajes esp= 18cm e mão-de-obra de apoio | 7d | 2010-12-08 | 2010-12-15 | 122SS+10d | 167d |  | AJUDANTE; PEDREIRO | 112h | 69,341.26 |
| 131 | 1.9.3.5 | **Concreto usinado** | 1d | 2010-12-15 | 2010-12-16 |  | 167d | 0d |  | 16h | 111,615.67 |
| 132 | 1.9.3.5.1 | Fornecimento e aplicação de concreto USINADO Fck=30 MPa - considerando BOMBEAMENTO (5% de perdas já incluído no custo) (6% de taxa p/ concr. bombeavel) | 1d | 2010-12-15 | 2010-12-16 | 125 | 167d |  | PEDREIRO; SERVENTE | 16h | 111,615.67 |
| 133 | 1.9.4 | **4ª Laje** | 34d | 2010-12-13 | 2011-01-16 |  | 164d | 0d |  | 816h | 427,301.08 |
| 134 | 1.9.4.1 | **Estrutura metálica** | 10d | 2010-12-13 | 2010-12-23 |  | 188d |  |  |  | 105,123.48 |
| 135 | 1.9.4.1.1 | Pilares metálicos com seções W - 360 x 79,0 kg/m e W - 360 x 122,0 kg/m em aço ASTM A-572 GR 50, inclusive chumbadores de 3/4", chapas metálicas e tratamento com jateamento mais pintura, conforme preojeto, inclusive fornecimento e montagem | 10d | 2010-12-13 | 2010-12-23 | 122 | 188d |  |  |  | 105,123.48 |
| 136 | 1.9.4.2 | **Escoramento metálico** | 6d | 2010-12-23 | 2010-12-29 |  | 167d | 0d |  |  | 25,402.05 |
| 137 | 1.9.4.2.1 | Escoramento metálico | 6d | 2010-12-23 | 2010-12-29 | 131FS+7d | 167d |  |  |  | 25,402.05 |
| 138 | 1.9.4.3 | **Forma** | 15d | 2010-12-29 | 2011-01-13 |  | 167d | 0d |  | 240h | 41,639.67 |
| 139 | 1.9.4.3.1 | Forma de chapas madeira compensada resinada, esp. 12mm, levando-se em conta a utilização 3 vezes, reforçadas com sarrafos de madeira de 2.5 x 10.0cm (incl material, corte, montagem, desforma, exclusive escoramento) | 15d | 2010-12-29 | 2011-01-13 | 136 | 167d |  | AJUDANTE; CARPINTEIRO | 240h | 29,628.06 |
| 140 | 1.9.4.3.2 | Forma de chapas madeira compensada resinada, esp. 12mm, levando-se em conta a utilização 3 vezes, reforçadas com sarrafos de madeira de 2.5 x 10.0cm (incl material, corte, montagem, escoras em eucalipto e desforma) | 15d | 2010-12-29 | 2011-01-13 | 136 | 167d |  |  |  | 12,011.61 |

| ID | WBS | Task | Duration | Start | Finish | Predecessors | Total slack | Free slack | Resources | Work | Cost |
| --- | --- | --- | --- | --- | --- | --- | --- | --- | --- | --- | --- |
| 141 | 1.9.4.4 | **Armação** | 7d | 2011-01-08 | 2011-01-15 |  | 164d | 0d |  | 560h | 143,520.2 |
| 142 | 1.9.4.4.1 | Fornecimento, dobragem e colocação em fôrma, de armadura CA-50 A média, diâmetro de 6.3 a 10.0 mm | 7d | 2011-01-08 | 2011-01-15 | 138SS+10d | 164d |  | AJUDANTE; FERREIRO | 112h | 14,701.95 |
| 143 | 1.9.4.4.2 | Fornecimento, dobragem e colocação em fôrma, de armadura CA-50 A grossa, diâmetro de 12.5 a 25.0mm | 7d | 2011-01-08 | 2011-01-15 | 138SS+10d | 164d |  | AJUDANTE; FERREIRO | 112h | 35,776.62 |
| 144 | 1.9.4.4.3 | Fornecimento, dobragem e colocação em forma, de armadura CA-60 B fina, diâmetro de 4.0 a 7.0mm | 7d | 2011-01-08 | 2011-01-15 | 138SS+10d | 164d |  | AJUDANTE; FERREIRO | 112h | 3,777.35 |
| 145 | 1.9.4.4.4 | Tela soldada em aço Q 138 CA-60 B, com malha de 10 x 10 cm, para armação | 7d | 2011-01-08 | 2011-01-15 | 138SS+10d | 164d |  | AJUDANTE; FERREIRO | 112h | 19,923.02 |
| 146 | 1.9.4.4.5 | Indice de preço p/ fornec. cordoalha engraxada CP 190 RB 12.7 mm (1/2"),incl. serviço protensão, c/ todos os acessórios p/o sistema de ancoragem ativa e passiva, em lajes esp= 18cm e mão-de-obra de apoio | 7d | 2011-01-08 | 2011-01-15 | 138SS+10d | 164d |  | AJUDANTE; PEDREIRO | 112h | 69,341.26 |
| 147 | 1.9.4.5 | **Concreto usinado** | 1d | 2011-01-15 | 2011-01-16 |  | 164d | 0d |  | 16h | 111,615.67 |
| 148 | 1.9.4.5.1 | Fornecimento e aplicação de concreto USINADO Fck=30 MPa - considerando BOMBEAMENTO (5% de perdas já incluído no custo) (6% de taxa p/ concr. bombeavel) | 1d | 2011-01-15 | 2011-01-16 | 141 | 164d |  | PEDREIRO; SERVENTE | 16h | 111,615.67 |
| 149 | 1.10 | **PAREDES E PAINÉIS** | 203d | 2010-10-15 | 2011-05-06 |  | 134d |  |  | 9928.09h | 394,480.76 |
| 150 | 1.10.1 | **Alvenaria Estrutural** | 11d | 2010-10-15 | 2010-10-26 |  | 333d |  |  | 306.98h | 19,850.62 |
| 151 | 1.10.1.1 | Alvenaria de blocos de concreto estrut. (14x19x39cm) cheios, c/ resist. mín. compr. 25MPa, assentados c/ arg. de cimento e areia no traço 1:4, esp. juntas 10mm e esp. da parede s/ revest. 14cm | 10d | 2010-10-15 | 2010-10-25 | 85 | 334d |  | PEDREIRO; SERVENTE | 147.56h | 6,579.12 |
| 152 | 1.10.1.2 | Alvenaria de blocos de concreto estrut. (19x19x39cm) cheios, c/ resist. mín. compr. 25MPa, assentados c/ arg. de cimento e areia no traço 1:4, esp. juntas 10mm e esp. da parede s/ revest. 19cm | 11d | 2010-10-15 | 2010-10-26 | 85 | 333d |  | PEDREIRO; SERVENTE | 159.42h | 13,271.5 |
| 153 | 1.10.2 | **Alvenaria de Vedação** | 100d | 2010-10-15 | 2011-01-23 |  | 134d | 0d |  | 9377.01h | 171,206.77 |
| 154 | 1.10.2.1 | Cobogó de concreto 40 x 40 x 10 cm , assentados com argamassa de cimento e areia no traço 1:3, espessura das juntas 15 mm | 12d | 2010-10-15 | 2010-10-27 | 85 | 222d |  | PEDREIRO [400%]; SERVENTE [400%] | 607.81h | 11,368.66 |
| 155 | 1.10.2.2 | Alvenaria de blocos cerâmicos 10 furos 10x20x20cm, assentados c/argamassa de cimento, cal hidratada CH1 e areia traço 1:0,5:8, esp. das juntas 12mm e esp. das paredes s/revestimento, 10cm (bloco comprado na fábrica, posto obra) | 100d | 2010-10-15 | 2011-01-23 | 85 | 134d |  | PEDREIRO [400%]; SERVENTE [400%] | 5951h | 79,146.27 |
| 156 | 1.10.2.3 | Alvenaria de blocos de concreto 19x19x39cm, c/ resist. mínimo a compres. 2.5 MPa, assent. c/ arg. de cimento, cal hidratada CH1 e areia no traço 1:0.5:8 esp. das juntas 10mm e esp. das paredes, s/ rev. 19cm | 48d | 2010-10-15 | 2010-12-02 | 85 | 186d |  | PEDREIRO [400%]; SERVENTE [400%] | 2818.2h | 80,691.84 |
| 157 | 1.10.3 | **Paredes de Gesso Acartonado** | 30d | 2011-02-15 | 2011-03-17 |  | 191d |  |  |  | 118,277.78 |
| 158 | 1.10.3.1 | Parede de gesso acartonado em chapa de gesso de 12,5mm, montante de 48 com distância de eixos de 40x40cm e altura de 3,25m com resistência a fogo e isolamento acústico com lã mineral - W111 73/48/400-ST/ST-LR 50 da Knauf ou equivalente | 30d | 2011-02-15 | 2011-03-17 | 267 | 191d |  |  |  | 69,662.24 |
| 159 | 1.10.3.2 | Parede de gesso acartonado (ÁREAS DE BANHEIRO-exceto parede hidráulica) em chapa de gesso de 12,5mm, montante de 48 com distância de eixos de 40x40cm e altura de 3,25m com resistência a fogo e isolamento acústico com lã mineral - W111 73/48/400-RU/RU-LR50 | 30d | 2011-02-15 | 2011-03-17 | 267 | 191d |  |  |  | 21,148.65 |
| 160 | 1.10.3.3 | Parede de gesso acartonado (PAREDES HIDRÁULICAS) em chapa de gesso de 12,5mm, montante de 48 com distância de eixos de 40x40cm e altura de 3,25m com resistência a fogo e isolamento acústico com lã mineral - W116 260/48/400 DEL-RU/RU-LR50 da Knauf ou equiv | 30d | 2011-02-15 | 2011-03-17 | 267 | 191d |  |  |  | 4,103.64 |
| 161 | 1.10.3.4 | Revestimento de gesso acartonado para fechamento de pilares metálicos e de vazios da circulação central em chapa de gesso de 12,5mm, apenas uma face do montante de 48 e altura de 3,25m com resistência a fogo - W111 73/48 da Knauf ou equivalente | 30d | 2011-02-15 | 2011-03-17 | 267 | 191d |  |  |  | 23,363.24 |
| 162 | 1.10.4 | **Divisórias de granito** | 7d | 2011-04-13 | 2011-04-20 |  | 157d |  |  | 224h | 26,086.81 |
| 163 | 1.10.4.1 | Divisória de granito Cinza Andorinha com 3 cm de espessura, fixada com cantoneira de ferro cromado | 7d | 2011-04-13 | 2011-04-20 | 259 | 157d |  | PEDREIRO [200%]; SERVENTE [200%] | 224h | 26,086.81 |
| 164 | 1.10.5 | **Painéis de madeira** | 30d | 2011-04-06 | 2011-05-06 |  | 141d |  |  |  | 57,407.25 |
| 165 | 1.10.5.1 | Fornecimento e instalação de parede divisória de painéis de chapa de fibra de madeira prensada com acabamento melamínico e miolo celular, esp. 35mm, módulo padrão 1,20 x 2,11m, na cor cinza cristal com perfis em aço zincado ou galvanizado NTR cor cinza, i | 30d | 2011-04-06 | 2011-05-06 | 385FF | 141d |  |  |  | 57,407.25 |

| ID | WBS | Task | Duration | Start | Finish | Predecessors | Total slack | Free slack | Resources | Work | Cost |
| --- | --- | --- | --- | --- | --- | --- | --- | --- | --- | --- | --- |
| 166 | 1.10.6 | **Vergas/Contravergas** | 1d | 2011-01-22 | 2011-01-23 |  | 244d |  |  | 20.1h | 1,651.55 |
| 167 | 1.10.6.1 | Verga/contraverga reta de concreto armado 10 x 5 cm, Fck = 15 MPa, inclusive forma, armação e desforma para portas, cobogós e janelas | 1d | 2011-01-22 | 2011-01-23 | 153FF | 244d |  | AJUDANTE; CARPINTEIRO; FERREIRO; PEDREIRO; SERVENTE | 20.1h | 1,651.55 |
| 168 | 1.11 | **ESQUADRIAS DE MADEIRA** | 72d | 2011-01-23 | 2011-04-05 |  | 172d |  |  | 1248h | 73,919.96 |
| 169 | 1.11.1 | **Marcos** | 10d | 2011-01-23 | 2011-02-02 |  | 234d |  |  | 496h | 11,883.19 |
| 170 | 1.11.1.1 | Marco de madeira de lei tipo Angelim, Curupixá, Ipê ou Cumaru, com 14 x 3,0 cm de batente, nas dimensões 0.80 x 2.10 m (para parede em alvenaria) | 10d | 2011-01-23 | 2011-02-02 | 153 | 234d |  | PEDREIRO; SERVENTE | 160h | 5,643.32 |
| 171 | 1.11.1.2 | Marco de madeira de lei tipo Angelim, Curupixá, Ipê ou Cumaru, com 14 x 3,0 cm de batente, nas dimensões 1.20 x 2.10 m (para parede em alvenaria) | 1d | 2011-01-23 | 2011-01-24 | 153 | 243d |  | PEDREIRO; SERVENTE | 16h | 854.34 |
| 172 | 1.11.1.3 | Marco de madeira de lei tipo Angelim, Curupixá, Ipê ou Cumaru, com 14 x 3,0 cm de batente, nas dimensões1.60 x 2.10 m (para parede em alvenaria) | 1d | 2011-01-23 | 2011-01-24 | 153 | 243d |  | PEDREIRO; SERVENTE | 16h | 458.76 |
| 173 | 1.11.1.4 | Marco de madeira de lei tipo Angelim, Curupixá, Ipê ou Cumaru, com 8 x 3,0 cm de batente, nas dimensões 0.80 x 2.10 m (para parede de gesso acartonado) | 9d | 2011-01-23 | 2011-02-01 | 153 | 235d |  | PEDREIRO; SERVENTE | 144h | 4,459.56 |
| 174 | 1.11.1.5 | Marco de madeira de lei tipo Angelim, Curupixá, Ipê ou Cumaru, com 8 x 3,0 cm de batente, nas dimensões 1.20 x 2.10 m (para parede de gesso acartonado) | 1d | 2011-01-23 | 2011-01-24 | 153 | 243d |  | PEDREIRO; SERVENTE | 16h | 344.04 |
| 175 | 1.11.1.6 | Marco de madeira de lei tipo Angelim, Curupixá, Ipê ou Cumaru, com 8 x 3,0 cm de batente, nas dimensões1.60 x 2.10 m (para parede de gesso acartonado) | 9d | 2011-01-23 | 2011-02-01 | 153 | 235d |  | PEDREIRO; SERVENTE | 144h | 123.17 |
| 176 | 1.11.2 | **Portas** | 15d | 2011-03-21 | 2011-04-05 |  | 172d |  |  | 752h | 62,036.77 |
| 177 | 1.11.2.1 | P1/P3 - Porta em madeira com enchimento sarrafeado, semi-ôca, com travessas de amarração embutidas, revestida em ambas as faces com folhas de compensado de Angelim, Curupixá, Ipê ou Cumaru, esp. 3mm, com acabamento em pintura esmalte sintético, conforme p | 15d | 2011-03-21 | 2011-04-05 | 266 | 172d |  | AJUDANTE [200%]; CARPINTEIRO [200%] | 480h | 35,270.82 |
| 178 | 1.11.2.2 | P2 - Porta em madeira com enchimento sarrafeado, semi-ôca, com travessas de amarração embutidas, revestida em ambas as faces com folhas de compensado de Angelim, Curupixá, Ipê ou Cumaru, esp. 3mm, com acabamento em laminado melamínico liso branco, para PN | 3d | 2011-03-21 | 2011-03-24 | 266 | 184d |  | AJUDANTE; CARPINTEIRO | 48h | 5,154.18 |
| 179 | 1.11.2.3 | P4/P7 - Porta em madeira com enchimento sarrafeado, semi-ôca, com travessas de amarração embutidas, revestida em ambas as faces com folhas de compensado de Angelim, Curupixá, Ipê ou Cumaru, esp. 3mm, com acabamento em pintura esmalte sintético, nas dimens | 5d | 2011-03-21 | 2011-03-26 | 266 | 182d |  | AJUDANTE; CARPINTEIRO | 80h | 5,939.55 |
| 180 | 1.11.2.4 | P6/P8 - Porta em madeira com enchimento sarrafeado, semi-ôca, com travessas de amarração embutidas, revestida em ambas as faces com folhas de compensado de Angelim, Curupixá, Ipê ou Cumaru, esp. 3mm, com acabamento em pintura esmalte sintético, nas dimens | 2d | 2011-03-21 | 2011-03-23 | 266 | 185d |  | AJUDANTE; CARPINTEIRO | 32h | 2,817.52 |
| 181 | 1.11.2.5 | P10 - Porta em madeira com enchimento sarrafeado, semi-ôca, com travessas de amarração embutidas, revestida em ambas as faces com folhas de compensado de Angelim, Curupixá, Ipê ou Cumaru, esp. 3mm, com acabamento em laminado melamínico liso branco, inclus | 7d | 2011-03-21 | 2011-03-28 | 266 | 180d |  | AJUDANTE; CARPINTEIRO | 112h | 12,854.7 |
| 182 | 1.12 | **ESQUADRIAS METÁLICAS** | 67d | 2011-01-23 | 2011-03-31 |  | 164d |  |  | 1767.04h | 916,191.74 |
| 183 | 1.12.1 | **Esquadrias alumínio** | 20d | 2011-01-23 | 2011-02-12 |  | 224d | 0d |  | 442.04h | 70,613.3 |
| 184 | 1.12.1.1 | J1 - Janela em alumínio anodizado, linha 25, cor natural, parte inferior fixa e superior básculante, conforme projeto, nas dimensões 1.90 x 1.60 m | 3d | 2011-01-23 | 2011-01-26 | 153 | 241d |  | PEDREIRO; SERVENTE | 36.16h | 3,661.48 |
| 185 | 1.12.1.2 | J2 - Janela em alumínio anodizado, linha 25, cor natural, de correr, conforme projeto, nas dimensões 3.50 x 1.00 m | 1d | 2011-01-23 | 2011-01-24 | 153 | 243d |  | PEDREIRO; SERVENTE | 11.5h | 891.38 |
| 186 | 1.12.1.3 | J3 - Janela em alumínio anodizado, linha 25, cor natural, fixa, conforme projeto, nas dimensões 2.00 x 1.00 m | 1d | 2011-01-23 | 2011-01-24 | 153 | 243d |  | PEDREIRO; SERVENTE | 10h | 654.34 |
| 187 | 1.12.1.4 | B1 - Báscula em alumínio anodizado, linha 25, cor natural, com parte fixa e basculante, conforme projeto, nas dimensões 0.60 x 1.20 m | 1d | 2011-01-23 | 2011-01-24 | 153 | 243d |  | PEDREIRO; SERVENTE | 10.88h | 867.16 |
| 188 | 1.12.1.5 | B2 - Báscula em alumínio anodizado, linha 25, cor natural, conforme projeto, nas dimensões 1.90 x 0.60 m | 3d | 2011-01-23 | 2011-01-26 | 153 | 241d |  | PEDREIRO; SERVENTE | 38.82h | 4,245.02 |
| 189 | 1.12.1.6 | PD2 - Porta de abrir tipo veneziana em alumínio anodizado natural, linha Suprema, fab. ALCOA, ou equivalente, com trinco livre/ ocupado, para fixação em divisória de granito com bucha de nylon e parafusos, nas dimensões 80x160cm | 20d | 2011-01-23 | 2011-02-12 | 153 | 224d |  | PEDREIRO; SERVENTE | 206.08h | 17,413.92 |
| 190 | 1.12.1.7 | PF5 - Portão basculante tipo veneziana em alumínio anodizado natural, linha Master, fab. ALCOA, ou equivalente em outra marca de igual ou superior desempenho, conforme projeto, nas dimenões 6.00 x 2.75m | 3d | 2011-01-23 | 2011-01-26 | 153 | 241d |  | PEDREIRO; SERVENTE | 39.6h | 23,616 |
| 191 | 1.12.1.8 | P9 - Porta em vidro temperado 10mm com película refletiva 70% prata, acabamento anodizado natural, inclusive programa de funcionamento automático com chave eletromecânica e chave programadora de cinco posições com ativadores por radar de sensibilidade di | 7d | 2011-01-23 | 2011-01-30 | 153 | 237d |  | PEDREIRO; SERVENTE | 89h | 19,264 |

| ID | WBS | Task | Duration | Start | Finish | Predecessors | Total slack | Free slack | Resources | Work | Cost |
| --- | --- | --- | --- | --- | --- | --- | --- | --- | --- | --- | --- |
| 192 | 1.12.2 | **Esquadrias alumínio p/ Pele de vidro** | 40d | 2011-01-23 | 2011-03-04 |  | 164d | 0d |  |  | 717,616.25 |
| 193 | 1.12.2.1 | Estrutura de alumínio anodizado para pele de vidro, exclusive vidro, conforme projeto | 40d | 2011-01-23 | 2011-03-04 | 133FS+7d | 164d |  |  |  | 717,616.25 |
| 194 | 1.12.3 | **Esquadrias alumínio p/ Iluminação Zenital** | 7d | 2011-02-07 | 2011-02-14 |  | 220d | 0d |  |  | 85,778.35 |
| 195 | 1.12.3.1 | Quadro de alumínio anodizado natural de 1,10 x 3,0 para vidro laminado 8mm(4+4) com película com polivinil butiral refletivo 70% cor prata, para cobertura do vazio da circulação central, exclusive o vidro, conforme projeto | 7d | 2011-02-07 | 2011-02-14 | 219 | 220d |  |  |  | 85,778.35 |
| 196 | 1.12.4 | **Grades e Portões** | 10d | 2011-03-21 | 2011-03-31 |  | 177d |  |  | 1325h | 42,183.83 |
| 197 | 1.12.4.1 | PCF1 - Porta corta-fogo, dim. 1,00x2,10 m, incl. pintura c/ tinta esmalte sintético na cor vermelho, a duas demãos, marca de referência Suvinil, incl. fundo anticorrosivo a uma demão, conforme detalhe | 10d | 2011-03-21 | 2011-03-31 | 266 | 177d |  | PEDREIRO [200%]; AJUDANTE [200%]; PINTOR [200%]; SERVENTE [200%] | 370h | 6,961.71 |
| 198 | 1.12.4.2 | PCF1 - Porta corta fogo nas dimensões 1.10 x 2.10 m, com fechadura, conforme detalhe | 10d | 2011-03-21 | 2011-03-31 | 266 | 177d |  | PEDREIRO [200%]; AJUDANTE [200%]; PINTOR [200%]; SERVENTE [200%] | 370h | 3,253.59 |
| 199 | 1.12.4.3 | PF1 - Portão de ferro de abrir em barra redonda Ø3/4" em aço SAE 1020, chapa de aço 3mm SAE 1045, inclusive dobradiça tipo caximbo, tranca tipo ferrolho em aço SAE 1020, conforme detalhe, nas dimensões 1.20 x 2.10m (Alojamentos) | 10d | 2011-03-21 | 2011-03-31 | 266 | 177d |  | AJUDANTE [200%]; PEDREIRO [200%]; PINTOR [200%]; SERVENTE [200%] | 202h | 19,943.6 |
| 200 | 1.12.4.4 | PF2 - Portão de ferro de abrir em barra chata 1 1/2 x 1/4", tubo de ferro galvanizado Ø2", inclusive gonzo com dobradiça, trinco com porta cadeado e trinco para piso, conforme detalhe, nas dimensões 2.00 x 2.50 m (Áreas Técnicas) | 10d | 2011-03-21 | 2011-03-31 | 266 | 177d |  | PEDREIRO [200%]; AJUDANTE [200%]; PINTOR [200%]; SERVENTE [200%] | 202h | 4,031.04 |
| 201 | 1.12.4.5 | PF3 - Portão de ferro de abrir em barra redonda Ø3/4" em aço SAE 1020, chapa de aço 3mm SAE 1045, inclusive dobradiça tipo caximbo, tranca tipo ferrolho em aço SAE 1020, conforme detalhe, nas dimensões 0.80 x 2.10m (Circulação dos Alojamentos) | 10d | 2011-03-21 | 2011-03-31 | 266 | 177d |  | PEDREIRO [200%]; AJUDANTE [200%]; PINTOR [200%]; SERVENTE [200%] | 181h | 2,945.04 |
| 202 | 1.12.4.6 | PF4- Portão de ferro de correr em barra redonda Ø3/4" em aço SAE 1020, chapa de aço 3mm SAE 1045, perfil U, cantoneira metálica 1 1/2"x1/4", inclusive roldanas, tranca tipo ferrolho em aço SAE 1020, conforme detalhe, nas dimensões 1.00 x 2.10 m | 10d | 2011-03-21 | 2011-03-31 | 266 | 177d |  |  |  | 2,131.72 |
| 203 | 1.12.4.7 | PF6- Portão de abrir aramado (Nylofor), duas folhas em arame zincado a fogo, gramatura 60 g/m², eletrosoldado, com pintura eletrostática em poliéster pó, espessura mínima 100 micras, conforme projeto, nas dimensões 2.00 x 2.50 m | 10d | 2011-03-21 | 2011-03-31 | 266 | 177d |  |  |  | 2,917.13 |
| 204 | 1.13 | **VIDROS E ESPELHOS** | 103d | 2011-01-23 | 2011-05-06 |  | 141d |  |  | 160h | 512,542.79 |
| 205 | 1.13.1 | **Vidro Esquadrias** | 20d | 2011-01-23 | 2011-02-12 |  | 224d | 0d |  |  | 2,479.09 |
| 206 | 1.13.1.1 | Vidro plano transparente liso, com 4 mm de espessura | 20d | 2011-01-23 | 2011-02-12 | 183SS | 224d |  |  |  | 2,479.09 |
| 207 | 1.13.2 | **Vidro Espelho Espião** | 1d | 2011-02-11 | 2011-02-12 |  | 224d |  |  |  | 4,096 |
| 208 | 1.13.2.1 | Vidro espião para sala de reconhecimentode vitímas, com 6mm de espessura, conforme projeto | 1d | 2011-02-11 | 2011-02-12 | 205FF | 224d |  |  |  | 4,096 |
| 209 | 1.13.3 | **Vidro laminado refletivo da Pele de vidro** | 20d | 2011-03-04 | 2011-03-24 |  | 164d | 0d |  |  | 452,496.38 |
| 210 | 1.13.3.1 | Vidro laminado 8mm(4+4) com película com polivinil butiral refletivo 70% cor prata, para pele de vidro, conforme projeto | 20d | 2011-03-04 | 2011-03-24 | 192 | 164d |  |  |  | 452,496.38 |
| 211 | 1.13.4 | **Vidro laminado refletivo p/ Iluminação Zenital** | 2d | 2011-02-14 | 2011-02-16 |  | 220d |  |  |  | 44,605.44 |
| 212 | 1.13.4.1 | Cobertura em vidro laminado reflexivo 70%, para iluminação Zanital, conforme projeto | 2d | 2011-02-14 | 2011-02-16 | 194 | 220d |  |  |  | 44,605.44 |
| 213 | 1.13.5 | **Espelhos** | 4d | 2011-05-02 | 2011-05-06 |  | 141d |  |  | 160h | 8,865.87 |
| 214 | 1.13.5.1 | Espelho prata 4mm, dim. 0,60 x 0,80 m, bisotado nas bordas, inclinado, colado e fixado com parafuso cromado sobre caixa de compensado naval 10mm, revestido com fórmica branca, acabamento texturizado nas laterais, conforme detalhe | 1d | 2011-05-05 | 2011-05-06 | 385FF | 141d |  | AJUDANTE [200%]; CARPINTEIRO [200%] | 32h | 1,127.94 |
| 215 | 1.13.5.2 | Espelho prata 4 mm, bisotado nas bordas, colado e fixado com parafuso cromado sobre caixa de compensado naval 10mm, revestido com fórmica branca acabamento texturizada nas laterais, conforme detalhe | 4d | 2011-05-02 | 2011-05-06 | 385FF | 141d |  | AJUDANTE [200%]; CARPINTEIRO [200%] | 128h | 7,737.93 |

| ID | WBS | Task | Duration | Start | Finish | Predecessors | Total slack | Free slack | Resources | Work | Cost |
| --- | --- | --- | --- | --- | --- | --- | --- | --- | --- | --- | --- |
| 216 | 1.14 | **COBERTURA** | 70d | 2010-12-14 | 2011-02-22 |  | 214d |  |  | 608h | 116,001.28 |
| 217 | 1.14.1 | **Estrutura metálica p/ Telha trapezoidal** | 15d | 2011-01-23 | 2011-02-07 |  | 214d | 0d |  |  | 44,436.15 |
| 218 | 1.14.1.1 | Estrutura metálica para telha trapezoidal galvanizada L40 espessura 0,65mm pré-pintada nas duas faces, ref. Eucatex ou equivalente, conforme projeto | 15d | 2011-01-23 | 2011-02-07 | 153 | 214d |  |  |  | 44,436.15 |
| 219 | 1.14.2 | **Estrutura metálica p/ Iluminação Zenital** | 1d | 2011-02-06 | 2011-02-07 |  | 220d | 0d |  |  | 20,602.93 |
| 220 | 1.14.2.1 | Estrutura metálica para cobertura do vazio da circulação central, conforme projeto | 1d | 2011-02-06 | 2011-02-07 | 217FF | 220d |  |  |  | 20,602.93 |
| 221 | 1.14.3 | **Telhado** | 15d | 2011-02-07 | 2011-02-22 |  | 214d |  |  | 240h | 21,122.19 |
| 222 | 1.14.3.1 | Fornecimento e instalação de telha trapezoidal galvanizada L40, espessura 0,65mm, pré-pintada nas duas faes, ref. Eucatex ou equivalente, conforme detallhe | 15d | 2011-02-07 | 2011-02-22 | 217 | 214d |  | AJUDANTE; TELHADISTA | 240h | 21,122.19 |
| 223 | 1.14.4 | **Rufos e Calhas** | 10d | 2010-12-14 | 2010-12-24 |  | 274d |  |  | 368h | 29,840.02 |
| 224 | 1.14.4.1 | Rufo lateral inferior (TRL) L40 e contra rufo (TKR) L40 de aço galvanizado ref. Eucatex ou equivalente | 10d | 2010-12-14 | 2010-12-24 | 264 | 274d |  | AJUDANTE; CARPINTEIRO | 160h | 3,126.64 |
| 225 | 1.14.4.2 | Calha de chapa de aço galvanizado nº26 de 40x60 cm, incl. 0.5%, conforme detalhe | 2d | 2010-12-14 | 2010-12-16 | 264 | 282d |  | AJUDANTE; CARPINTEIRO | 32h | 6,921.24 |
| 226 | 1.14.4.3 | Pingadeira calha (TPG) L40 da Eucatex ou equivalente, coforme detalhe | 2d | 2010-12-14 | 2010-12-16 | 264 | 282d |  | AJUDANTE; CARPINTEIRO | 32h | 2,404.64 |
| 227 | 1.14.4.4 | Rufo chapeu em alumínio anodizado natural com largura de 15 cm, conforme detalhe | 2d | 2010-12-14 | 2010-12-16 | 264 | 282d |  | AJUDANTE; CARPINTEIRO | 32h | 5,170 |
| 228 | 1.14.4.5 | Rufo chapeu em alumínio anodizado natural com largura de 20 cm , conforme projeto | 5d | 2010-12-14 | 2010-12-19 | 264 | 279d |  | AJUDANTE; CARPINTEIRO | 80h | 3,817.5 |
| 229 | 1.14.4.6 | Rufo chapeu em alumínio anodizado natural com largura de 30 cm, para pele de vidro, conforme projeto | 2d | 2010-12-14 | 2010-12-16 | 264 | 282d |  | AJUDANTE; PEDREIRO | 32h | 8,400 |
| 230 | 1.15 | **IMPERMEABILIZAÇÃO** | 135d | 2010-09-23 | 2011-02-05 |  | 231d |  |  | 568h | 329,591.5 |
| 231 | 1.15.1 | **Laje piso, blocos e baldrames - Térreo** | 10d | 2010-09-23 | 2010-10-03 |  | 356d |  |  | 80h | 105,514.84 |
| 232 | 1.15.1.1 | Impermeabilização de blocos e baldrame do térreo conforme projeto e memorial descritivo | 10d | 2010-09-23 | 2010-10-03 | 81 | 356d |  | SERVENTE | 80h | 105,514.84 |
| 233 | 1.15.2 | **Poço elevador** | 5d | 2010-09-23 | 2010-09-28 |  | 361d |  |  | 80h | 1,740.92 |
| 234 | 1.15.2.1 | Impermeabilização do poço do elevador,conforme projeto e memorial descritivo | 5d | 2010-09-23 | 2010-09-28 | 81 | 361d |  | PEDREIRO; SERVENTE | 80h | 1,740.92 |
| 235 | 1.15.3 | **Laje da praça 1º pavto** | 10d | 2010-10-15 | 2010-10-25 |  | 334d |  |  | 240h | 64,124.2 |
| 236 | 1.15.3.1 | Impermeabilização da laje da praça do 1º pavimento,conforme projeto e memorial descritivo | 10d | 2010-10-15 | 2010-10-25 | 99 | 334d |  | COLOCADOR; PEDREIRO; SERVENTE | 240h | 64,124.2 |
| 237 | 1.15.4 | **Jardineiras 1º pavto** | 7d | 2010-10-22 | 2010-10-29 |  | 330d |  |  | 168h | 37,706.03 |
| 238 | 1.15.4.1 | Impermeabilização das jardineiras do 1º pavimento,conforme projeto e memorial descritivo | 7d | 2010-10-22 | 2010-10-29 | 99FS+7d | 330d |  | COLOCADOR; PEDREIRO; SERVENTE | 168h | 37,706.03 |
| 239 | 1.15.5 | **Rampas acesso 1º pavto** | 5d | 2010-10-22 | 2010-10-27 |  | 332d |  |  |  | 19,720.31 |
| 240 | 1.15.5.1 | Impermeabilização das rampas de acesso do 1º pavimento,conforme projeto e memorial descritivo | 5d | 2010-10-22 | 2010-10-27 | 99FS+7d | 332d |  |  |  | 19,720.31 |

| ID | WBS | Task | Duration | Start | Finish | Predecessors | Total slack | Free slack | Resources | Work | Cost |
| --- | --- | --- | --- | --- | --- | --- | --- | --- | --- | --- | --- |
| 241 | 1.15.6 | **Sanitários, Vestiários, Copas e Áreas de serviço e Laje sob telhado** | 10d | 2011-01-26 | 2011-02-05 |  | 231d |  |  |  | 23,408.84 |
| 242 | 1.15.6.1 | Impermeabilização dos sanitários, vestiários, copas, área de serviço e laje sob telhado,conforme projeto e memorial descritivo | 10d | 2011-01-26 | 2011-02-05 | 147FS+10d | 231d |  |  |  | 23,408.84 |
| 243 | 1.15.7 | **Vestiários, Copa e Área de serviço - Térreo** | 7d | 2010-10-30 | 2010-11-06 |  | 322d |  |  |  | 6,699.04 |
| 244 | 1.15.7.1 | Impermeabilização dos vestiários, copa, área de serviço do térreo,conforme projeto e memorial descritivo | 7d | 2010-10-30 | 2010-11-06 | 99FS+15d | 322d |  |  |  | 6,699.04 |
| 245 | 1.15.8 | **Marquise e Laje impermeabilizada Cobertura (descoberta)** | 10d | 2011-01-16 | 2011-01-26 |  | 241d |  |  |  | 64,236.31 |
| 246 | 1.15.8.1 | Impermeabilização da marquise, laje da cobertura (descoberta),conforme projeto e memorial descritivo | 10d | 2011-01-16 | 2011-01-26 | 147 | 241d |  |  |  | 64,236.31 |
| 247 | 1.15.9 | **Barrilete** | 5d | 2011-01-26 | 2011-01-31 |  | 236d |  |  |  | 6,441.01 |
| 248 | 1.15.9.1 | Impermeabilização do barrilete,conforme projeto e memorial descritivo | 5d | 2011-01-26 | 2011-01-31 | 147FS+10d | 236d |  |  |  | 6,441.01 |
| 249 | 1.16 | **TETOS E FORROS** | 40d | 2011-04-03 | 2011-05-13 |  | 134d |  |  | 160h | 250,955.83 |
| 250 | 1.16.1 | **Argamassa** | 10d | 2011-04-03 | 2011-04-13 |  | 164d |  |  | 160h | 749.49 |
| 251 | 1.16.1.1 | Gesso corrido para escada e marquise, conforme projeto | 10d | 2011-04-03 | 2011-04-13 | 257FF | 164d |  | PEDREIRO; SERVENTE | 160h | 749.49 |
| 252 | 1.16.2 | **Rebaixamento** | 30d | 2011-04-13 | 2011-05-13 |  | 134d |  |  |  | 250,206.35 |
| 253 | 1.16.2.1 | Forro em gesso acartonado, conforme projeto | 30d | 2011-04-13 | 2011-05-13 | 259 | 134d |  |  |  | 34,451.33 |
| 254 | 1.16.2.2 | Sanca em gesso para as salas, conforme projeto | 30d | 2011-04-13 | 2011-05-13 | 259 | 134d |  |  |  | 46,170.46 |
| 255 | 1.16.2.3 | Forro acústico painel de fibra mineral modulado, nas dimensões 625x625, esp.=13mm com cor branca, resistente a fungo e fogo com sistema estrutural em perfil T invertido - SK 15, com largura de 15mm da linha Ecomin Antaris da AMF Knalf ou euquivalente | 30d | 2011-04-13 | 2011-05-13 | 259 | 134d |  |  |  | 169,584.56 |
| 256 | 1.17 | **REVESTIMENTO DE PAREDES** | 150d | 2010-11-14 | 2011-04-13 |  | 154d |  |  | 18293.9h | 321,365.45 |
| 257 | 1.17.1 | **Argamassa** | 100d | 2011-01-03 | 2011-04-13 |  | 134d | 0d |  | 17061.9h | 157,114.33 |
| 258 | 1.17.1.1 | Reboco de argamassa de cimento, cal hidratada e areia média ou grossa lavada no traço 1:0.5:6, espessura 20 mm - | 100d | 2011-01-03 | 2011-04-13 | 153FS-20d | 134d |  | PEDREIRO [1100%]; SERVENTE [1100%] | 17061.9h | 157,114.33 |
| 259 | 1.17.2 | **Acabamento interno** | 40d | 2011-03-04 | 2011-04-13 |  | 134d | 0d |  | 1232h | 48,210.43 |
| 260 | 1.17.2.1 | Cerâmica 10x10cm, ref. Camburi branco da Eliane, Cecrisa ou Portobelo em argamassa colante, rejunte Junta Plus Fina, cinza claro, esp. 3mm | 6d | 2011-04-07 | 2011-04-13 | 257FF | 134d |  | LADRILHISTA; SERVENTE | 72.03h | 6,110.3 |
| 261 | 1.17.2.2 | Cerâmica 20 x 20 cm, Slim Branco, ref. Eliane ou equiv, juntas a prumo empregando argamassa de cimento colante, inclusive rejuntamento com junta Plus fina esp 3mm, cor cinza claro | 40d | 2011-03-04 | 2011-04-13 | 257FF | 134d |  | AZULEJISTA [200%]; SERVENTE [200%] | 1038.15h | 39,434.67 |
| 262 | 1.17.2.3 | Acabamento de alumínio com perfil de canto para arremate das paredes | 5d | 2011-04-08 | 2011-04-13 | 257FF | 134d |  | AZULEJISTA; SERVENTE | 40.41h | 725.35 |
| 263 | 1.17.2.4 | Rodaparede em granito Cinza Andorinha ou Corumbá, H= 7 cm e esp. 2 cm, conforme projeto | 6d | 2011-04-07 | 2011-04-13 | 257FF | 134d |  | GRANITEIRO; SERVENTE | 81.41h | 1,940.11 |
| 264 | 1.17.3 | **Acabamento externo** | 30d | 2010-11-14 | 2010-12-14 |  | 274d | 0d |  |  | 116,040.69 |
| 265 | 1.17.3.1 | Placas Cimentícias com espessura de 10mm fixados no bloco cerâmico com montantes e guias de 90 x 40mm e /ou 200 x 400mm e acabamento de resina sintética, marca de referência Eterplac, Brasiplac ou equivalente | 30d | 2010-11-14 | 2010-12-14 | 153SS+30d | 274d |  |  |  | 116,040.69 |

| ID | WBS | Task | Duration | Start | Finish | Predecessors | Total slack | Free slack | Resources | Work | Cost |
| --- | --- | --- | --- | --- | --- | --- | --- | --- | --- | --- | --- |
| 266 | 1.18 | **PISOS INTERNOS E EXTERNOS** | 64d | 2011-01-16 | 2011-03-21 |  | 172d | 0d |  | 4945.55h | 676,938.01 |
| 267 | 1.18.1 | **Acabamentos** | 30d | 2011-01-16 | 2011-02-15 |  | 172d | 0d |  | 1650.11h | 615,890.79 |
| 268 | 1.18.1.1 | Piso elevado de placas de pedra natural Metasilitito Laminado ou Ardósia de 60 x 60cm com esp. de 25mm sob suportes telescópicos de altura regualável de polipropileno inclusive acabamento vinílico em placa de 60 x 60 cm, com espessura de 2mm na cor 604 - | 30d | 2011-01-16 | 2011-02-15 | 133 | 172d |  |  |  | 174,537.53 |
| 269 | 1.18.1.2 | Piso elevado sob suportes telescópicos de altura regualável de polipropileno inclusive acabamento em granito polido Cinza Andorinha, Corumbá ou equivalente, em placa de 60 x 60 cm, de 2.0 cm de espessura, calibrado, conforme projeto | 30d | 2011-01-16 | 2011-02-15 | 133 | 172d |  |  |  | 391,661.57 |
| 270 | 1.18.1.3 | Contrapiso em concreto não estrutural leve com vermiculita expandida, conforme projeto | 1d | 2011-01-16 | 2011-01-17 | 133 | 201d |  |  |  | 22,842.58 |
| 271 | 1.18.1.4 | Piso de alta resistência, acabamento polido, na cor cinza claro, do tipo granilite, de acordo com as normas da ABNT 2.100 grupo B. A junta plástica de dilatação 7 x 3 mm, executada com requadro de 1,0 x 1,0m. Com grânulos na proporção de 30% preto e 70% b | 11d | 2011-01-16 | 2011-01-27 | 133 | 191d |  | GRANILITEIRO [300%]; SERVENTE [300%] | 528h | 7,114.31 |
| 272 | 1.18.1.5 | Piso de alta resistência, acabamento antiderrapante, na cor cinza claro, do tipo granilite, de acordo com as normas da ABNT 2.100 grupo B. A junta plástica de dilatação 7 x 3 mm, executada com requadro de 1,0 x 1,0m. Com grânulos na proporção de 30% preto | 14d | 2011-01-16 | 2011-01-30 | 133 | 188d |  | GRANILITEIRO [300%]; SERVENTE [300%] | 672h | 8,821.99 |
| 273 | 1.18.1.6 | Resina epóxi, marca de referência International ou similar em outra marca de igual ou superior desempenho. | 15d | 2011-01-16 | 2011-01-31 | 133 | 187d |  | AJUDANTE [300%]; PINTOR [300%] | 450.11h | 10,912.81 |
| 274 | 1.18.2 | **Degraus, Rodapés, Soleira e Peitoris** | 34d | 2011-02-15 | 2011-03-21 |  | 172d |  |  | 3295.44h | 61,047.23 |
| 275 | 1.18.2.1 | Soleria em granito Cinza Andorinha ou Corumbá largura 15 cm, conforme projeto | 34d | 2011-02-15 | 2011-03-21 | 267 | 172d |  | PEDREIRO [400%]; SERVENTE [400%] | 1825.97h | 949.7 |
| 276 | 1.18.2.2 | Soleria em granito Cinza Andorinha ou Corumbá, largura 10 cm, conforme projeto | 6d | 2011-02-15 | 2011-02-21 | 267 | 200d |  | PEDREIRO [400%]; SERVENTE [400%] | 323.58h | 104.16 |
| 277 | 1.18.2.3 | Soleria em "L" para o vazio da circulação central, conforme projeto | 1d | 2011-02-15 | 2011-02-16 | 267 | 205d |  | PEDREIRO [400%]; SERVENTE [400%] | 48.72h | 4,770 |
| 278 | 1.18.2.4 | Rodapé em granito Cinza Andorinha ou Corumbá, h = 7 cm, conforme projeto | 1d | 2011-02-15 | 2011-02-16 | 267 | 205d |  | PEDREIRO [400%]; SERVENTE [400%] | 34.4h | 26,653.74 |
| 279 | 1.18.2.5 | Rodapé em granito Cinza Andorinha ou Corumbá, h= 20 cm, conforme projeto | 1d | 2011-02-15 | 2011-02-16 | 267 | 205d |  | PEDREIRO [400%]; SERVENTE [400%] | 47.2h | 10,196.16 |
| 280 | 1.18.2.6 | Peitoril em granito Cinza Andorinha ou Corumbá, largura 10 cm, conforme projeto | 1d | 2011-02-15 | 2011-02-16 | 267 | 205d |  | PEDREIRO [400%]; SERVENTE [400%] | 49.05h | 521.3 |
| 281 | 1.18.2.7 | Peitoril em granito Cinza Andorinha ou Corumbá, largura 13 cm, conforme projeto | 1d | 2011-02-15 | 2011-02-16 | 267 | 205d |  | PEDREIRO [400%]; SERVENTE [400%] | 60.81h | 970 |
| 282 | 1.18.2.8 | Peitoril em granito Cinza Andorinha ou Corumbá, largura 13 cm c/ pingadeira,conforme projeto | 1d | 2011-02-15 | 2011-02-16 | 267 | 205d |  | PEDREIRO [400%]; SERVENTE [400%] | 36.03h | 137.95 |
| 283 | 1.18.2.9 | Peitoril em granito Cinza Andorinha ou Corumbá, largura 18 cm, conforme projeto | 1d | 2011-02-15 | 2011-02-16 | 267 | 205d |  | PEDREIRO [400%]; SERVENTE [400%] | 58.88h | 1,083.52 |
| 284 | 1.18.2.10 | Peitoril em granito Cinza Andorinha ou Corumbá, largura 18 cm c/ pingadeira dos dois lados, conforme projeto | 3d | 2011-02-15 | 2011-02-18 | 267 | 203d |  | PEDREIRO [400%]; SERVENTE [400%] | 185.04h | 3,924.12 |
| 285 | 1.18.2.11 | Marco em granito Cinza Andorinha ou Corumbá, largura 20 cm, conforme projeto | 7d | 2011-02-15 | 2011-02-22 | 267 | 199d |  | PEDREIRO [400%]; SERVENTE [400%] | 440.72h | 10,330.32 |
| 286 | 1.18.2.12 | Soleria de granilite, largura de 15cm, conforme projeto | 3d | 2011-02-15 | 2011-02-18 | 267 | 203d |  | PEDREIRO [400%]; SERVENTE [400%] | 185.04h | 1,406.25 |
| 287 | 1.19 | INSTALAÇÕES DIVERSAS | 240d | 2010-10-15 | 2011-06-12 | 85 | 104d |  |  |  | 3,026,075.52 |
| 288 | 1.20 | **LOUÇAS E METAIS** | 15d | 2011-04-13 | 2011-04-28 |  | 149d |  |  | 1059.95h | 143,246.7 |
| 289 | 1.20.1 | **Louças** | 15d | 2011-04-13 | 2011-04-28 |  | 149d |  |  | 496h | 36,777.89 |
| 290 | 1.20.1.1 | Saboneteira de louça branca, ref. A180, marca de referência Deca ou equivalente em outra marca de igual ou superior desempenho | 1d | 2011-04-13 | 2011-04-14 | 259 | 163d |  | AZULEJISTA; SERVENTE | 16h | 163.32 |
| 291 | 1.20.1.2 | Lavátorio de canto suspenso - ref. 04013, cor branca, marca de ref. Celite ou equivalente em outra marca de igual ou superior desempenho | 2d | 2011-04-13 | 2011-04-15 | 259 | 162d |  | AJUDANTE; ENCANADOR | 32h | 1,466.16 |
| 292 | 1.20.1.3 | Lavátorio com coluna suspensa - ref. L51+CS 1V, cor branca, marca de referência Deca ou similar em outra marca de igual ou superior desempenho | 1d | 2011-04-13 | 2011-04-14 | 259 | 163d |  | AJUDANTE; ENCANADOR | 16h | 454.37 |
| 293 | 1.20.1.4 | Cuba louça branca oval, de embutir, Mod. L37, marca de ref. Deca incl. válvula e sifão, exclusive torneira. | 7d | 2011-04-13 | 2011-04-20 | 259 | 157d |  | AJUDANTE; ENCANADOR | 112h | 9,614.52 |
| 294 | 1.20.1.5 | Bacia Handicapped com caixa acoplada linha Stylus Excellence - ref. 54510 e 54510, marca de referência Celite ou equivalente em outra marca de igual ou superior desempenho | 3d | 2011-04-13 | 2011-04-16 | 259 | 161d |  | AJUDANTE; ENCANADOR | 48h | 4,633.02 |
| 295 | 1.20.1.6 | Bacia com caixa acoplada de louça branca – Linha Targa - ref. CP 101, marca de referência Deca ou similar em outra marca de igual ou superior desempenho e assento universal branco, ref.: TPJ, marca de referência Astra ou similar de igual ou superior desem | 15d | 2011-04-13 | 2011-04-28 | 259 | 149d |  | AJUDANTE; ENCANADOR | 240h | 18,120.48 |
| 296 | 1.20.1.7 | Mictório de louça branca, com sifão integrado, mod. M712 marca de ref. Deca ou equivalente, inclusive válvula e engates cromados | 2d | 2011-04-13 | 2011-04-15 | 259 | 162d |  | AJUDANTE; ENCANADOR | 32h | 2,326.02 |

| ID | WBS | Task | Duration | Start | Finish | Predecessors | Total slack | Resources | Work | Cost |
| --- | --- | --- | --- | --- | --- | --- | --- | --- | --- | --- |
| 297 | 1.20.2 | **Bancadas** | 4d | 2011-04-13 | 2011-04-17 |  | 160d |  | 291.95h | 14,206.86 |
| 298 | 1.20.2.1 | Bancada e Rodabanca (h=10cm) de granito Cinza Andorinha ou Corumbá, polido com acabamento de 4 cm de espessura, onde serão instaladas cubas de embutir, conforme detalhe em projeto - dimensões 3,00 x 0,60 cm - Área de serviço 1º,2º e 3º bloco Sul | 2d | 2011-04-13 | 2011-04-15 | 257 | 162d | AJUDANTE; PEDREIRO; PINTOR; SERVENTE | 32.36h | 2,209.23 |
| 299 | 1.20.2.2 | Bancada e Rodabanca (h=10 cm) de granito Cinza Andorinha ou Corumbá, polido com acabamento de 4 cm de espessura, onde serão instaladas cubas de embutir, conforme detalhe em projeto - dimensões 2,90 x 0,60 cm (bancada seca) + 1,55 x 0,60 cm (bancada molh | 1d | 2011-04-13 | 2011-04-14 | 257 | 163d | AJUDANTE; PEDREIRO; PINTOR; SERVENTE | 16.12h | 931.08 |
| 300 | 1.20.2.3 | Bancada e Rodabanca de granito Cinza Andorinha ou Corumbá, polido com acabamento de 4 cm de espessura, onde serão instaladas cubas de embutir, conforme detalhe em projeto - dimensões 2,39 x 0,60 cm - DML - Agente | 1d | 2011-04-13 | 2011-04-14 | 257 | 163d | AJUDANTE; PEDREIRO; PINTOR; SERVENTE | 16.12h | 543.64 |
| 301 | 1.20.2.4 | Bancada e Rodabanca (h=12 cm) de granito Cinza Andorinha ou Corumbá, polido com acabamento de 4 cm de espessura, onde serão instaladas cubas de embutir, conforme detalhe em projeto - dimensões 2,07 x 0,55 cm - Sanitários 1º,2º e 3º bloco Sul | 3d | 2011-04-13 | 2011-04-16 | 257 | 161d | AJUDANTE; PEDREIRO; PINTOR; SERVENTE | 48.72h | 2,993.82 |
| 302 | 1.20.2.5 | Bancada e Rodabanca (h=12 cm) granito de Cinza Andorinha ou Corumbá, polido com acabamento de 4 cm de espessura, onde serão instaladas cubas de embutir, conforme detalhe em projeto - dimensões 1,97 x 0,55 cm - Sanitários 1º,2º e 3º bloco norte | 1d | 2011-04-13 | 2011-04-14 | 257 | 163d | AJUDANTE; PEDREIRO; PINTOR; SERVENTE | 16.24h | 950.1 |
| 303 | 1.20.2.6 | Bancada e Rodabanca (h=12 cm) de granito Cinza Andorinha ou Corumbá, polido com acabamento de 4 cm de espessura, onde serão instaladas cubas de embutir, conforme detalhe em projeto - dimensões 1,92 x 0,55 cm - Sanitários 1º,2º e 3º bloco norte | 2d | 2011-04-13 | 2011-04-15 | 257 | 162d | AJUDANTE; PEDREIRO; PINTOR; SERVENTE | 32.48h | 1,852.28 |
| 304 | 1.20.2.7 | Bancada e Rodabanca (h=7 cm) de granito Cinza Andorinha ou Corumbá, polido com acabamento de 4 cm de espessura, onde serão instaladas cubas de embutir, conforme detalhe em projeto - dimensões 1,70 x 0,55 cm - Vestiário tercerizado e funcionários | 2d | 2011-04-13 | 2011-04-15 | 257 | 162d | AJUDANTE; PEDREIRO; PINTOR; SERVENTE | 32.36h | 1,144.59 |
| 305 | 1.20.2.8 | Bancada e Rodabanca (h=10 cm) de granito Cinza Andorinha ou Corumbá, polido com acabamento de 4 cm de espessura, onde serão instaladas cubas de embutir, conforme detalhe em projeto - dimensões 1,50 x 0,60 cm (bancada molhada) e 0,81 x 0,60 cm (bancada se | 1d | 2011-04-13 | 2011-04-14 | 257 | 163d | AJUDANTE; PEDREIRO; PINTOR; SERVENTE | 16.24h | 1,003.24 |
| 306 | 1.20.2.9 | Bancada e Rodabanca (h= 10 cm) de granito Cinza Andorinha ou Corumbá, polido com acabamento de 4 cm de espessura, onde serão instaladas cubas de embutir, conforme detalhe em projeto - dimensões 1,64 x 0,60 cm - Copa Juíses | 1d | 2011-04-13 | 2011-04-14 | 257 | 163d | AJUDANTE; PEDREIRO; PINTOR; SERVENTE | 16.24h | 755.12 |
| 307 | 1.20.2.10 | Bancada e Rodabanca (h=7cm) de granito Cinza Andorinha ou Corumbá, polido com acabamento de 4 cm de espessura, onde serão instaladas cubas de embutir, conforme detalhe em projeto - dimensões 0,97 x 0,55 cm - Sanitários Administrativos | 4d | 2011-04-13 | 2011-04-17 | 257 | 160d | AJUDANTE; PEDREIRO; PINTOR; SERVENTE | 65.07h | 1,823.76 |
| 308 | 1.20.3 | **Metais** | 3d | 2011-04-13 | 2011-04-16 |  | 161d |  | 112h | 17,826.44 |
| 309 | 1.20.3.1 | Torneira de mesa para lavatório Compact - Pressmatic ref. 17160606 - cromada com fechamento automático, marca de referência Docol ou Equivalente em outra de igual ou superior desempenho | 3d | 2011-04-13 | 2011-04-16 | 259 | 161d | AJUDANTE; ENCANDOR | 48h | 12,057.93 |
| 310 | 1.20.3.2 | Torneira para tanque, marcas de referência Fabrimar, Deca ou Docol | 1d | 2011-04-13 | 2011-04-14 | 259 | 163d | AJUDANTE; ENCANDOR | 16h | 649.18 |
| 311 | 1.20.3.3 | Torneira Pressmatic Benefit, marca de referência Docol ou similar | 1d | 2011-04-13 | 2011-04-14 | 259 | 163d | AJUDANTE; ENCANDOR | 16h | 3,686.04 |
| 312 | 1.20.3.4 | Torneira para jardim de 3/4" marcas de referência Fabrimar, Deca ou Docol | 1d | 2011-04-13 | 2011-04-14 | 259 | 163d | AJUDANTE; ENCANDOR | 16h | 347.64 |
| 313 | 1.20.3.5 | Torneira de parede Articulável cromada, marcas de referência Fabrimar, Deca ou Docol | 1d | 2011-04-13 | 2011-04-14 | 259 | 163d | AJUDANTE; ENCANDOR | 16h | 1,085.65 |
| 314 | 1.20.4 | **Outros aparelhos** | 3d | 2011-04-13 | 2011-04-16 |  | 161d |  | 160h | 74,435.51 |
| 315 | 1.20.4.1 | Dispenser para papel toalha em plástico ABS, cor branco | 1d | 2011-04-13 | 2011-04-14 | 259 | 163d |  |  | 1,670.76 |
| 316 | 1.20.4.2 | Dispenser para sabonete líquido em plástico ABS, cor branco | 1d | 2011-04-13 | 2011-04-14 | 259 | 163d |  |  | 1,757.7 |
| 317 | 1.20.4.3 | Dispenser para papel papel higiêncio (rolão), em plástico ABS, cor branco | 1d | 2011-04-13 | 2011-04-14 | 259 | 163d |  |  | 2,394.21 |
| 318 | 1.20.4.4 | Cuba em Aço Inox ref. Nº 2 Walter D. Fischer, ou ref. 312, marca Strake, ou ref. 94084 linha Standard marca Tramontina, inclusive válvula de metal e sifão cromado | 1d | 2011-04-13 | 2011-04-14 | 259 | 163d |  |  | 1,605.4 |
| 319 | 1.20.4.5 | Tanque simples de aço inox Fischer, mod. TQ1-S AISI 304, ou equivalente nas marcas Metalpress ou Mekal, inclusive válvula de metal 1 1/4" e sifão cromado 2", excl. torneira | 3d | 2011-04-13 | 2011-04-16 | 259 | 161d | AJUDANTE; ENCANADOR | 48h | 6,112.54 |
| 320 | 1.20.4.6 | Ducha manual Acqua jet , linha Aquarius, com registro ref.C 2195, marcas de referência Fabrimar, Deca ou Docol | 1d | 2011-04-13 | 2011-04-14 | 259 | 163d | AJUDANTE; ENCANADOR | 16h | 1,909.16 |
| 321 | 1.20.4.7 | Chuveiro antivandalismo de sobrepor linha Alta Segurança – Chrome da Docol ou equivalente | 1d | 2011-04-13 | 2011-04-14 | 259 | 163d | AJUDANTE; ENCANADOR | 16h | 6,468.9 |
| 322 | 1.20.4.8 | Chuveiro elétrico, marca de referência Lorenzete ou equivalente | 1d | 2011-04-13 | 2011-04-14 | 259 | 163d | AJUDANTE; ENCANADOR | 16h | 146.34 |
| 323 | 1.20.4.9 | Bebedouro individual conjugado ref. IBBL BAG 40 ou equivalente em outra marca de igual ou superior desempenho | 2d | 2011-04-13 | 2011-04-15 | 259 | 162d | AJUDANTE; ENCANADOR | 32h | 8,496.6 |
| 324 | 1.20.4.10 | Combinado (vaso sanitário, lavatório e bebedouro) antivandalismo. Estrutura de aço inoxidável de 2 mm de espessura, qualidade AISI 304, soldado integralmente com sistema de atmosfera inerte com acabamento sanitário, Ref. S2 CD-LI-PM da Caaguazu ou equival | 2d | 2011-04-13 | 2011-04-15 | 259 | 162d | AJUDANTE; ENCANADOR | 32h | 43,873.9 |

| ID | WBS | Task | Duration | Start | Finish | Predecessors | Total slack | Resources | Work | Cost |
| --- | --- | --- | --- | --- | --- | --- | --- | --- | --- | --- |
| 325 | 1.21 | **PINTURA** | 110d | 2011-03-04 | 2011-06-22 |  | 0d |  | 14750.8h | 172,399.82 |
| 326 | 1.21.1 | **sobre Paredes e Forros** | 90d | 2011-03-04 | 2011-06-02 |  | 0d |  | 10718.9h | 126,097.37 |
| 327 | 1.21.1.1 | Emassamento de paredes e forros, com duas demãos de massa à base de PVA, marcas de referência Suvinil, Coral ou Metalatex | 90d | 2011-03-04 | 2011-06-02 | 259SS | 0d | AJUDANTE; PINTOR | 877.31h | 5,977.86 |
| 328 | 1.21.1.2 | Emassamento de paredes e forros, com duas demãos de massa acrílica, marcas de referência Suvinil, Coral ou Metalatex | 90d | 2011-03-04 | 2011-06-02 | 259SS | 0d | AJUDANTE [300%]; PINTOR [300%] | 3692.85h | 60,455.6 |
| 329 | 1.21.1.3 | Pintura com tinta látex PVA, marcas de referência Suvinil, Coral ou Metalatex, inclusive selador em paredes e forros a duas demãos | 90d | 2011-03-04 | 2011-06-02 | 259SS | 0d | AJUDANTE; PINTOR | 995.3h | 7,543.11 |
| 330 | 1.21.1.4 | Pintura com tinta acrílica, na cor branca marcas de referência Suvinil, Coral ou Metalatex, inclusive selador acrílico, em paredes e forros, a duas demãos | 90d | 2011-03-04 | 2011-06-02 | 259SS | 0d | AJUDANTE [300%]; PINTOR [300%] | 3713.41h | 44,827.03 |
| 331 | 1.21.1.5 | Textura lisa acrílica, em paredes, a uma demão, inclusive selador | 90d | 2011-03-04 | 2011-06-02 | 259SS | 0d | AJUDANTE; PINTOR | 1440h | 5,403.16 |
| 332 | 1.21.1.6 | Pintura de parede com altura até 1.10m do piso com faixas e 20cm, na cor amarela em esmalte sintético, marca de referência Coral, ou equivalente nas marcas Suvinil ou Metalatex. | 90d | 2011-03-04 | 2011-06-02 | 259SS | 0d |  |  | 945.3 |
| 333 | 1.21.1.7 | Pintura de parede com altura até 1.10m do piso com faixas e 20cm na cor preta em esmalte sintético, marca de referência Coral, ou equivalente nas marcas Suvinil ou Metalatex. | 90d | 2011-03-04 | 2011-06-02 | 259SS | 0d |  |  | 945.3 |
| 334 | 1.21.2 | **sobre Concreto, Blocos ou Placas cimentícias** | 45d | 2011-04-18 | 2011-06-02 |  | 114d |  | 1856.5h | 21,008.63 |
| 335 | 1.21.2.1 | Pintura com tinta acrílica na cor branca, marcas de referência Suvinil, Coral ou Metalatex, inclusive selador acrílico, em cobogós de concreto a duas demãos | 45d | 2011-04-18 | 2011-06-02 | 326FF | 114d | AJUDANTE; PINTOR | 671.33h | 7,653.48 |
| 336 | 1.21.2.2 | Caiação de meio-fio a três demãos | 10d | 2011-05-23 | 2011-06-02 | 326FF | 114d | AJUDANTE; PINTOR | 147.93h | 591.01 |
| 337 | 1.21.2.3 | Pintura com tinta esmalte sintético, na cor vermelha marcas de referência Suvinil, Coral ou Metalatex, inclusive selador acrílico, em paredes e forros, a duas demãos, conforme projeto | 2d | 2011-05-31 | 2011-06-02 | 326FF | 114d | AJUDANTE; PINTOR | 29.64h | 249.23 |
| 338 | 1.21.2.4 | Pintura com tinta esmalte sintético, na cor azul marcas de referência Suvinil, Coral ou Metalatex, inclusive selador acrílico, em paredes e forros, a duas demãos, conforme projeto | 7d | 2011-05-26 | 2011-06-02 | 326FF | 114d | AJUDANTE; PINTOR | 90.11h | 623.08 |
| 339 | 1.21.2.5 | Pintura com tinta esmalte sintético, na cor areia marcas de referência Suvinil, Coral ou Metalatex, inclusive selador acrílico, em paredes e forros, a duas demãos, conforme projeto | 40d | 2011-04-23 | 2011-06-02 | 326FF | 114d | AJUDANTE; PINTOR | 597.49h | 5,068.89 |
| 340 | 1.21.2.6 | Resina acrílica impermeabilizante multiuso ref. Hydronorth ou equivalente, sobre placa cimentícia com duas demãos conforme recomendado pelo fabricante | 20d | 2011-05-13 | 2011-06-02 | 326FF | 114d | AJUDANTE; PINTOR | 320h | 6,822.94 |
| 341 | 1.21.3 | **sobre Madeira** | 15d | 2011-05-18 | 2011-06-02 |  | 114d |  | 399.94h | 5,474.38 |
| 342 | 1.21.3.1 | Pintura com tinta esmalte sintético, marcas de referência Suvinil, Coral ou Metalatex, inclusive fundo branco nivelador, em madeira a duas demãos | 15d | 2011-05-18 | 2011-06-02 | 326FF | 114d | AJUDANTE [200%]; PINTOR [200%] | 399.94h | 5,474.38 |
| 343 | 1.21.4 | **sobre Metal** | 7d | 2011-05-26 | 2011-06-02 |  | 114d |  | 73.04h | 1,267.85 |
| 344 | 1.21.4.1 | Pintura com tinta esmalte sintético, marcas de referência Suvinil, Coral ou Metalatex, a duas demãos, inclusive fundo anticorrosivo a uma demão em metal | 7d | 2011-05-26 | 2011-06-02 | 326FF | 114d | AJUDANTE; PINTOR | 73.04h | 912.28 |
| 345 | 1.21.4.2 | Pintura dos pilares com altura até 1.10m do piso com faixas e 20cm, na cor amarela em esmalte sintético, marca de referência Coral, ou equivalente nas marcas Suvinil ou Metalatex. | 7d | 2011-05-26 | 2011-06-02 | 326FF | 114d |  |  | 177.79 |
| 346 | 1.21.4.3 | Pintura dos pilares com altura até 1.10m do piso com faixas e 20cm, na cor preta em esmalte sintético, marca de referência Coral, ou equivalente nas marcas Suvinil ou Metalatex. | 7d | 2011-05-26 | 2011-06-02 | 326FF | 114d |  |  | 177.79 |
| 347 | 1.21.5 | **sobre Pisos** | 20d | 2011-06-02 | 2011-06-22 |  | 0d |  | 1702.4h | 18,551.6 |
| 348 | 1.21.5.1 | Simbolo internacional de acesso p/deficiente em pintura à base de epoxi p/ piso, marcas de ref. Nova Cor, Coral, Suvinil ou equiv. pictograma branco sobre fundo azul, ref.Munsell 10B5/10 ou Pantone 2925C conf. NBR 9050, dim. 80x80cm | 20d | 2011-06-02 | 2011-06-22 | 326 | 0d | AJUDANTE [700%]; PINTOR [700%] | 1702.4h | 679.2 |
| 349 | 1.21.5.2 | Pintura com tinta branca com acabamento acrílico modificado, marcas de referência Intersheen 579 da International ou equivalente, para demarcação da faixa de estacionamento, largura de 8 cm | 7d | 2011-06-02 | 2011-06-09 | 326 | 13d |  |  | 17,872.4 |

| ID | WBS | Task | Duration | Start | Finish | Predecessors | Total slack | Resources | Work | Cost |
| --- | --- | --- | --- | --- | --- | --- | --- | --- | --- | --- |
| 350 | 1.22 | **SERVIÇOS COMPLEMENTARES EXTERNOS** | 90d | 2011-03-24 | 2011-06-22 |  | 60d |  | 12023.5h | 388,895.51 |
| 351 | 1.22.1 | **Muros e Fechamentos** | 55d | 2011-04-28 | 2011-06-22 |  | 94d |  | 6732.47h | 102,476 |
| 352 | 1.22.1.1 | Gradil externo nas dimensões 2.03 x 2.50, com mureta em alv. de bl. cerâmicos 10x20x20 cm, H=40 cm, com pilares e cintas de trav. em concreto arm. a cada 3 m, inclusive chap., reboco e pint. acríl. a duas demãos | 27d | 2011-05-26 | 2011-06-22 | 356FF | 94d | PINTOR; PEDREIRO; FERREIRO; CARPINTEIRO; AJUDANTE; SERVENTE | 461.71h | 23,219.66 |
| 353 | 1.22.1.2 | Gradil externo nas dimensões 2.03 x 1,00, instalado sobre mureta da rampa | 4d | 2011-06-18 | 2011-06-22 | 356FF | 94d | AJUDANTE; CARPINTEIRO; FERREIRO; PEDREIRO; PINTOR; SERVENTE | 69.41h | 1,225.02 |
| 354 | 1.22.1.3 | Muro de alvenaria de blocos cerâmicos 10x20x20cm, c/ pilares a cada 2m. esp. 10cm e h=2.5m, revestido, reboco e textura acrílica a uma demão, incl. pilares, cintas e sapatas | 33d | 2011-05-20 | 2011-06-22 | 356FF | 94d | AJUDANTE [200%]; CARPINTEIRO [200%]; FERREIRO [200%]; PEDREIRO [200%]; PINTOR [200%]; SERVENTE [200%] | 1433.21h | 26,927.03 |
| 355 | 1.22.1.4 | Muro de alvenaria de blocos cerâmicos 10x20x20cm, c/ pilares a cada 2m. esp. 10cm e h=2.5m, revestido, reboco e textura acrílica a uma demão inclusive fundação em bloco de concreto estrutural cheio 14x19x39cm | 55d | 2011-04-28 | 2011-06-22 | 356FF | 94d | AJUDANTE [400%]; CARPINTEIRO [400%]; FERREIRO [400%]; PEDREIRO [400%]; PINTOR [400%]; SERVENTE [400%] | 4768.14h | 51,104.28 |
| 356 | 1.22.2 | **Pavimentação** | 30d | 2011-05-23 | 2011-06-22 |  | 0d |  | 4320.43h | 128,740.99 |
| 357 | 1.22.2.1 | Meio-fio de concreto pré-moldado com dimensões de 15x12x30x100 cm, rejuntados com argamassa de cimento e areia no traço 1:3 | 17d | 2011-06-05 | 2011-06-22 | 347FF | 0d | CALCETEIRO [200%]; SERVENTE [200%] | 406.78h | 7,679.48 |
| 358 | 1.22.2.2 | Blocos pré-moldados de concreto tipo pavi-s ou equivalente, espessura de 8 cm e resistência a compressão mínima de 35MPa, assentados sobre colchão de pó de pedra na espessura de 10 cm, na cor cinza | 30d | 2011-05-23 | 2011-06-22 | 347FF | 0d | CALCETEIRO; SERVENTE | 346.95h | 25,533.25 |
| 359 | 1.22.2.3 | Blocos pré-moldados de concreto tipo pavi-s ou equivalente, espessura de 8 cm e resistência a compressão mínima de 35MPa, assentados sobre colchão de pó de pedra na espessura de 10 cm, na cor vermelho | 30d | 2011-05-23 | 2011-06-22 | 347FF | 0d | CALCETEIRO; SERVENTE | 346.95h | 35,633.54 |
| 360 | 1.22.2.4 | Acabamento (polimento) para piso em concreto, com friso a cada 10cm para rampa | 3d | 2011-06-19 | 2011-06-22 | 347FF | 0d | CALCETEIRO; SERVENTE | 33.09h | 2,339.54 |
| 361 | 1.22.2.5 | Piso de argamassa de alta resistência tipo granilite ou equivalente de qualidade comprovada, espessura de 10mm, com juntas plástica em quadros de 1m, na cor natural, com acabamento anti-derrapante, inclusive regularização, para rampa | 30d | 2011-05-23 | 2011-06-22 | 347FF | 0d | GRANILITEIRO; SERVENTE | 480h | 5,931.37 |
| 362 | 1.22.2.6 | Fornecimento e assentamento de ladrilho hidráulico ranhurado liso, cinza, dim. 20x20 cm, esp. 1.5cm, assentado com pasta de cimento colante, inclusive lastro de concreto regularizado com 8 cm de espessura | 30d | 2011-05-23 | 2011-06-22 | 347FF | 0d | PEDREIRO [500%]; SERVENTE [500%] | 1726.5h | 22,620 |
| 363 | 1.22.2.7 | Fornecimento e assentamento de ladrilho hidráulico ranhurado, cinza, dim. 20x20 cm, esp. 1.5cm, assentado com pasta de cimento colante, inclusive lastro de concreto regularizado com 8 cm de espessura | 30d | 2011-05-23 | 2011-06-22 | 347FF | 0d | LADRILHISTA; PEDREIRO; SERVENTE | 720h | 23,940.99 |
| 364 | 1.22.2.8 | Fornecimento e assentamento de ladrilho hidráulico pastilhado, vermelho, dim. 20x20 cm, esp. 1.5cm, assentado com pasta de cimento colante, inclusive lastro de concreto regularizado com 8 cm de espessura | 30d | 2011-05-23 | 2011-06-22 | 347FF | 0d | LADRILHISTA; PEDREIRO; SERVENTE | 260.16h | 5,062.82 |
| 365 | 1.22.3 | **Paisagismo** | 15d | 2011-06-07 | 2011-06-22 |  | 94d |  | 168h | 12,944.46 |
| 366 | 1.22.3.1 | Fornecimento e plantio de grama em placas tipo esmeralda, inclusive terra vegetal, conforme projeto | 15d | 2011-06-07 | 2011-06-22 | 356FF | 94d | JARDINEIRO | 120h | 7,647.57 |
| 367 | 1.22.3.2 | Fornecimento e plantio de mudas de Dracena Malaia, inclusive terra vegetal, h= 0,60 m, conforme projeto | 1d | 2011-06-21 | 2011-06-22 | 356FF | 94d | JARDINEIRO | 8h | 3,245.5 |
| 368 | 1.22.3.3 | Fornecimento e plantio de mudas de Iuca-Elefante, inclusive terra vegetal, h= 1,00 mconforme projeto | 1d | 2011-06-21 | 2011-06-22 | 356FF | 94d | JARDINEIRO | 8h | 846.32 |
| 369 | 1.22.3.4 | Fornecimento e plantio de mudas de Agave dragão, inclusive terra vegetal, h= 0,40 m, conforme projeto | 1d | 2011-06-21 | 2011-06-22 | 356FF | 94d | JARDINEIRO | 8h | 390.48 |
| 370 | 1.22.3.5 | Fornecimento e plantio de mudas Ipê-Rosa, inclusive terra vegetal, h= 1,80/2,50 m, conforme projeto | 1d | 2011-06-21 | 2011-06-22 | 356FF | 94d | JARDINEIRO | 8h | 125.98 |
| 371 | 1.22.3.6 | Fornecimento e plantio de mudas Ipê-Amarelo, inclusive terra vegetal, h= 1,80 /2,50 m, conforme projeto | 1d | 2011-06-21 | 2011-06-22 | 356FF | 94d | JARDINEIRO | 8h | 80.1 |
| 372 | 1.22.3.7 | Fornecimento e plantio de mudas Palmeira Imperial, inclusive terra vegetal, 4,00/6,00 m, conforme projeto | 1d | 2011-06-21 | 2011-06-22 | 356FF | 94d | JARDINEIRO | 8h | 608.51 |
| 373 | 1.22.4 | **Diversos externos** | 2d | 2011-06-20 | 2011-06-22 |  | 0d |  | 162.62h | 18,691.35 |
| 374 | 1.22.4.1 | Conjunto de 03 mastros, para bandeira, em ferro galvanizado, 2 com 7,50m de altura e 1 com 9,0m de altura, nos diâmetros de 4", 3" e 2", inclusive base de concreto, conf. detalhe de projeto | 2d | 2011-06-20 | 2011-06-22 | 356FF | 0d | AJUDANTE; CARPINTEIRO; FERREIRO; PEDREIRO; PINTOR; SERVENTE | 41.49h | 5,485.76 |
| 375 | 1.22.4.2 | Letreiro da fachada composto de caixa de inox polido de esp. 15cm com tampo de placa de acrílico branco com película colorida adesivada por trás conforme logomarca (azul, verde, laranja e amarelo) com iluminação por trás, conforme projeto | 2d | 2011-06-20 | 2011-06-22 | 356FF | 0d | PEDREIRO; SERVENTE | 32h | 10,341.12 |
| 376 | 1.22.4.3 | Placa de acrílico de 30x12cm e 5mm de espessura com fundo amarelo e letras pretas para aviso de “ÁGUA NÃO POTÁVEL” , para as torneira de jardim | 2d | 2011-06-20 | 2011-06-22 | 356FF | 0d | AJUDANTE; PEDREIRO; PINTOR; SERVENTE | 36.39h | 106.92 |
| 377 | 1.22.4.4 | Placa de inauguração de obra executada de alumínio fundido, dim. 0.40x0.50m, inclusive fixação utilizando argamassa de cimento e areia | 2d | 2011-06-20 | 2011-06-22 | 356FF | 0d | PEDREIRO; SERVENTE | 32h | 678.77 |
| 378 | 1.22.4.5 | Bicicletário em tubo de ferro galvanizado 1" e ferro liso 1/2", inclusive pintura | 2d | 2011-06-20 | 2011-06-22 | 356FF | 0d | AJUDANTE; PEDREIRO; PINTOR; SERVENTE | 20.74h | 2,078.78 |

| ID | WBS | Task | Type | Duration | Start | Finish | Predecessors | Total slack | Free slack | Resources | Work | Cost |
| --- | --- | --- | --- | --- | --- | --- | --- | --- | --- | --- | --- | --- |
| 379 | 1.22.5 | **Brises** |  | 20d | 2011-03-24 | 2011-04-13 |  | 164d |  |  | 640h | 126,042.72 |
| 380 | 1.22.5.1 | Brise horizontal linear LC100, liso 45º Refax, cor alumínio natural |  | 20d | 2011-03-24 | 2011-04-13 | 209 | 164d |  | PEDREIRO; SERVENTE | 320h | 65,452.08 |
| 381 | 1.22.5.2 | Tela de malha de 2x2cm de arame galvanizado 1/2" fio 12, com quadro em tubo de ferro galvanizado 1 1/2” e cantoneira de ferro 1/2"x1/2"x1/8", conforme detalhe, para proteção do brise |  | 20d | 2011-03-24 | 2011-04-13 | 209 | 164d |  | PEDREIRO; SERVENTE | 320h | 60,590.64 |
| 382 | 1.23 | **SERVIÇOS COMPLEMENTARES INTERNOS** |  | 23d | 2011-04-13 | 2011-05-06 |  | 141d |  |  | 952.26h | 156,636.92 |
| 383 | 1.23.1 | **Armários e Prateleiras** |  | 16d | 2011-04-13 | 2011-04-29 |  | 141d | 0d |  | 256h | 10,601.03 |
| 384 | 1.23.1.1 | Prateleiras em granito Cinza Andorinha, esp. 2cm |  | 16d | 2011-04-13 | 2011-04-29 | 259 | 141d |  | PEDREIRO; SERVENTE | 256h | 10,601.03 |
| 385 | 1.23.2 | **Diversos internos** |  | 23d | 2011-04-13 | 2011-05-06 |  | 141d | 0d |  | 696.26h | 146,035.89 |
| 386 | 1.23.2.1 | Guarda corpo do vazio da circulação central em tubo circular de alumínio anodizado Ø10.6cm, perfil "U" em alumínio de 2.6 x 3.8cm parafusado no montante para apoio do vidro, inclusive vidro laminado de 8mm, pontaletes de 4.5 x 4cm de alumínio e canopla p |  | 7d | 2011-04-29 | 2011-05-06 | 383 | 141d |  | AJUDANTE; PEDREIRO; PINTOR; SERVENTE | 134.36h | 72,118.59 |
| 387 | 1.23.2.2 | Corrimão para a escada de serviço em tubo de ferro galvanizado ∅2" soldado ao suporte em tubo de ferro galvanizado ∅3/4'', a cada 1,5m, exclusive pintura, conforme detalhe |  | 7d | 2011-04-29 | 2011-05-06 | 383 | 141d |  | AJUDANTE; PEDREIRO; PINTOR; SERVENTE | 68.91h | 6,150.43 |
| 388 | 1.23.2.3 | Guarda corpo com corrimão único para a escada social em tubo de aço inox Ø2" polido soldado ao suporte em tubo de aço inox Ø3/4", a cada 1,50m, conforme projeto |  | 7d | 2011-04-29 | 2011-05-06 | 383 | 141d |  | AJUDANTE; PEDREIRO; PINTOR; SERVENTE | 114.47h | 24,165.2 |
| 389 | 1.23.2.4 | Guarda corpo para a escada externa frontal do prédio de tubo de aço inox ∅2" polido soldado ao suporte em tubo de aço inox ∅3/4'', a cada 1,5m com corrimão único de tubo de aço inox ∅2" polido soldado ao guarda corpo, conforme projeto |  | 7d | 2011-04-29 | 2011-05-06 | 383 | 141d |  | AJUDANTE; PEDREIRO; PINTOR; SERVENTE | 65.43h | 11,570.96 |
| 390 | 1.23.2.5 | Corrimão para a escada social em tubo de aço inox Ø2" polido, conforme projeto |  | 7d | 2011-04-29 | 2011-05-06 | 383 | 141d |  | AJUDANTE; PEDREIRO; PINTOR; SERVENTE | 89.09h | 8,029.98 |
| 391 | 1.23.2.6 | Corrimão para a escada externa do prédio em tubo de aço inox Ø2" polido conforme projeto |  | 7d | 2011-04-29 | 2011-05-06 | 383 | 141d |  | PEDREIRO; SERVENTE | 112h | 6,433.06 |
| 392 | 1.23.2.7 | Corrimão duplo, para a rampa externa, em tubo de aço inox ∅2" polido soldado ao suporte em tubo de aço inox ∅3/4'', a cada 1,5m fixado no peitoril de concreto, exclusive peitoril, conforme projeto |  | 7d | 2011-04-29 | 2011-05-06 | 383 | 141d |  | PEDREIRO; SERVENTE | 112h | 4,023.24 |
| 393 | 1.23.2.8 | Barra de apoio para lavatório em aço inox formato UPHD SYSTEMS - COD EAN 920, ou equivalente de igual ou superior desempenho. |  | 7d | 2011-04-29 | 2011-05-06 | 383 | 141d |  |  |  | 3,050.58 |
| 394 | 1.23.2.9 | Barra de apoio de 80 cm, ref. 2310 EBR marca de ref. Deca, ou ref. 00446416 marca de ref. Docol, ou similar em outra marca de igual desempenho |  | 7d | 2011-04-29 | 2011-05-06 | 383 | 141d |  |  |  | 7,333.32 |
| 395 | 1.23.2.10 | Guichê em esquadria fixa de alumínio anodizado, conforme projeto, nas dimensões de 1,70x1,10 m |  | 3d | 2011-04-13 | 2011-04-16 | 259 | 161d |  |  |  | 2,149.16 |
| 396 | 1.23.2.11 | Guichê em esquadria fixa de alumínio anodizado, conforme projeto, nas dimensões de 3,20x1,10 m |  | 3d | 2011-04-13 | 2011-04-16 | 259 | 161d |  |  |  | 1,011.37 |
| 397 | 1.24 | **TRATAMENTO, CONSERVAÇÃO E LIMPEZA** |  | 10d | 2011-06-16 | 2011-06-26 |  | 0d |  |  | 80h | 28,847.63 |
| 398 | 1.24.1 | Limpeza geral da obra |  | 10d | 2011-06-16 | 2011-06-26 | 373FF+4d | 90d |  | SERVENTE | 80h | 27,885.46 |
| 399 | 1.24.2 | Limpeza geral de obras (quadras, praças e jardins) |  | 10d | 2011-06-16 | 2011-06-26 | 373FF+4d | 0d |  |  |  | 962.17 |
| 400 | 1.25 | TERMO DE RECEBIMENTO PROVISÓRIO | milestone | 0d | 2011-06-26 | 2011-06-26 | 399FF | 0d |  |  |  |  |
| 401 | 1.26 | TERMO DE RECEBIMENTO DEFINITIVO | milestone | 0d | 2011-09-24 | 2011-09-24 | 400FF+90d | 0d |  |  |  |  |
| 402 | 2 | (ajuste de centavos) | milestone | 0d | 2010-06-01 | 2010-06-01 |  | 480d |  |  |  | 0.04 |
